# 3GPP_Release-2000

Schedule from MS Project, 2000-01-03 to 2007-01-19, A marks actual dates.

## Calendars

- Standard: Mon-Fri 08:00-12:00, 13:00-17:00; Sat-Sun off.

## Resources

| Resource |
| --- |
| NP |
| N1 |
| N2 |
| N3 |
| N4 |
| N5 |
| TP |
| T1 |
| T2 |
| T3 |
| RP |
| R1 |
| R2 |
| R3 |
| R4 |
| SP |
| S1 |
| S2 |
| S3 |
| S4 |
| S5 |
| PCG |
| GP |
| No |
| CN4 |
| ? |
| WG G2 |
| G2 |
| G1 |
| G4 |
| G3 |
| All |
| Generic |
| MLST |
| G5 |
| S3; G2 |
| WG T2 |
| GP;G1 |
| G4;G5 |
| OMA |
| GP-G2 |
| Yes |
| GP; |
| N4; |
| GP; N1 |
| CT5 |
| C5 |
| C1 |
| C4 |
| C3 |
| C6 |
| G1; |
| 4 |

## Schedule

| ID | WBS | Task | Duration | Start | Finish | Complete | Remaining | Baseline start | Baseline finish | Baseline duration | Total slack | Constraint | Resources | Work | Actual work | Text9 | Text6 | Text1 | Text3 | Text4 | Text5 | Text7 | Text8 | Text2 | Text12 |
| --- | --- | --- | --- | --- | --- | --- | --- | --- | --- | --- | --- | --- | --- | --- | --- | --- | --- | --- | --- | --- | --- | --- | --- | --- | --- |
| 1 | 1 | VERSION 2005 December 23rd | 1d | 2000-01-03 | 2000-01-03 |  |  | 2000-01-03 | 2000-01-03 | 1d | 1839d |  |  |  |  | 2044 |  |  |  |  |  |  |  |  |  |
| 2 | 2 | "CTRL + a" to display all the 3GPP fields | 1d | 2000-01-03 | 2000-01-03 |  |  | 2000-01-03 | 2000-01-03 | 1d | 1839d |  |  |  |  | 1462 |  |  |  |  |  |  |  |  |  |
| 3 | 3 | Content of Release 7, not frozen | 1d | 2000-01-03 | 2000-01-03 |  |  | 2000-01-03 | 2000-01-03 | 1d | 1839d |  |  |  |  | 2058 |  |  |  |  |  |  |  |  |  |
| 5 | 4 | Rel-7 Features listed below | 1d? | 2000-01-03 | 2000-01-03 |  |  | 2000-01-03 | 2000-01-03 | 1d? | 1839d |  |  |  |  |  | Rel-7 |  |  |  |  |  |  |  |  |
| 6 | 8.5 | **Multiple Input Multiple Output antennas (MIMO)** | 850d? | 2003-03-14 A | 2006-06-15 | 17% | 707.36d? | 2003-03-14 | 2005-12-15 | 720d? | 156d |  | R1 | 30360h | 6052.8h | 2468 | Rel-7 | MIMO | TR25.876,TR25.996 | Howard Huang, Lucent | hchuang@lucent.com | TSG | Cesar |  |  |
| 7 | 5.1 | MIMO - Physical layer | 720d? | 2003-09-12 A | 2006-06-15 | 65% | 252d? | 2003-09-12 | 2005-12-15 | 590d? | 156d | finish no earlier than 2006-06-15 | R1 | 5760h | 3744h |  | Rel-7 | MIMO-Phys | 25.211, 25.212, 25.213, 25.214, 25.215, 25.221, 25 | Howard Huang, Lucent | hchuang@lucent.com | TSG | MCC_RAN |  |  |
| 8 | 5.2 | MIMO - Layer 2,3 aspects | 720d? | 2003-09-12 | 2006-06-15 |  |  | 2003-09-12 | 2005-12-15 | 589d? | 156d | finish no earlier than 2006-06-15 | R2 | 5760h |  |  | Rel-7 | MIMO-L23 | TR 25.876 | Howard Huang, Lucent | hchuang@lucent.com | TSG | MCC_RAN |  |  |
| 9 | 5.3 | MIMO - Iub/Iur Protocol Aspects | 850d? | 2003-03-14 | 2006-06-15 |  |  | 2003-03-14 | 2005-12-15 | 719d? | 156d | finish no earlier than 2006-06-15 | R3 | 6800h |  |  | Rel-7 | MIMO-IurIub |  | Howard Huang, Lucent | hchuang@lucent.com | TSG | MCC_RAN |  |  |
| 10 | 5.4 | MIMO - RF Radio Transmission/Reception, System Performance Requirements and Conformance Testing | 655d? | 2003-12-12 A | 2006-06-15 | 4% | 628.8d? | 2003-12-12 | 2005-12-15 | 524d? | 156d | finish no earlier than 2006-06-15 | R4 | 5240h | 209.6h |  | Rel-7 | MIMO-RF |  | Man Hung Ng, Lucent | ngm@lucent.com | TSG | MCC_RAN |  |  |
| 11 | 6 | **PS domain and IMS impacts for supporting IMS Emergency calls** | 1545.1d? | 2000-07-07 A | 2006-06-09 | 21% | 1215.27d? | 2000-08-14 | 2006-06-09 | 1520d? | 160d |  | S2 | 101988h | 19183.9h |  | Rel-7 | EMC1 |  | Rainer Liebhart |  | TSG | Maurice |  |  |
| 12 | 10.1.1 | Service Requirements for IP-based emergency calls | 985d | 2000-09-18 A | 2004-06-25 A | 100% |  | 2000-09-18 | 2004-06-25 | 985d |  | finish no earlier than 2004-06-25 | S1 | 7880h | 7880h | 1314 | Rel-7 | EMC1 | 22.976 |  |  |  |  | CCaR |  |
| 13 | 6.2 | Study on Stage 2 for IMS-level solution | 668d? | 2003-02-26 A | 2005-09-16 A | 100% |  | 2003-02-26 | 2005-09-16 | 668d? |  | finish no earlier than 2005-09-16 | S2 | 5344h | 5344h |  | Rel-7 | EMC1 | 23.228, 23.060, 23.002 | Rainer Liebhart, Siemenws |  | TSG |  |  |  |
| 14 | 6.3 | Study on Stage 2 for GPRS-level solution | 301d? | 2004-10-14 A | 2005-12-08 A | 100% |  | 2004-10-14 | 2005-12-08 | 301d? |  | finish no earlier than 2005-12-08 | S2 | 2408h | 2408h |  | Rel-7 | EMC1 |  |  |  |  |  |  |  |
| 15 | 6.4 | Stage 2 Specification Phase - IMS-level | 200d? | 2005-09-05 A | 2006-06-09 | 30% | 140d? | 2005-09-05 | 2006-06-09 | 200d? | 160d | finish no earlier than 2006-06-09 | S2 | 1600h | 480h |  | Rel-7 | EMC1 |  |  |  |  |  |  |  |
| 16 | 6.5 | Stage 2 Specification Phase - GPRS-level | 200d? | 2005-09-05 A | 2006-06-09 | 10% | 180d? | 2005-09-05 | 2006-06-09 | 200d? | 160d | finish no earlier than 2006-06-09 | S2 | 1600h | 160h |  | Rel-7 | EMC1 |  |  |  |  |  |  |  |
| 17 | 10.1 | **Emergency Call Enhancements for IP& PS Based Calls – stage 3** | 1540.1d | 2000-07-07 A | 2006-06-02 | 1% | 1530.75d | 2000-08-14 | 2005-07-11 | 1280.1d | 165d |  | C1 | 71195.6h | 358.78h | 1653 | Rel-7 | EMC1 |  | Alf Heidermark (Ericsson) | alf.heidermark@ericsson.com |  |  | CCaR |  |
| 18 | 10.1.2 | CT1 IMS aspects to support IMS Emergency sessions | 1444.82d | 2000-10-17 | 2006-06-02 |  |  | 2000-10-17 | 2005-07-08 | 1209d | 165d | finish no earlier than 2006-06-02 | C1 | 11558.6h |  | 1315 | Rel-7 | EMC1 | 24.229 | Mr Atle Monrad, Ericsson | Atle.Monrad@eto.ericsson.se |  |  | CCaR |  |
| 19 | 10.1.2 | CT3 IMS aspects to support IMS Emergency sessions | 1444.82d | 2000-11-20 | 2006-06-02 |  |  | 2000-10-17 | 2005-07-08 | 1209d | 165d | finish no earlier than 2006-06-02 | C3 | 11558.6h |  | 1315 | Rel-7 | EMC1 | 29.613 | Mr Atle Monrad, Ericsson | Atle.Monrad@eto.ericsson.se |  |  | CCaR |  |
| 20 | 10.1.5 | CT1 PS domain aspects to support IMS Emergency sessions | 1515d | 2000-07-07 A | 2006-06-02 | 3% | 1470.15d | 2000-08-14 | 2005-07-11 | 1255d | 165d | finish no earlier than 2006-06-02 | C1 | 12120h | 358.78h | 1646 | Rel-7 | EMC1 | 24.008 | Mr Atle Monrad, Ericsson | Atle.Monrad@eto.ericsson.se |  |  | CCaR |  |
| 21 | 10.1.5 | CT3 PS domain aspects to support IMS Emergency sessions | 1489.9d | 2000-09-18 | 2006-06-02 |  |  | 2000-08-14 | 2005-07-11 | 1255d | 165d | finish no earlier than 2006-06-02 | C3 | 11919.2h |  | 1646 | Rel-7 | EMC1 | 29.061 | Mr Atle Monrad, Ericsson | Atle.Monrad@eto.ericsson.se |  |  | CCaR |  |
| 22 | 10.1.5 | CT4 PS domain aspects to support IMS Emergency sessions | 1489.9d | 2000-09-18 | 2006-06-02 |  |  | 2000-08-14 | 2005-07-11 | 1255d | 165d | finish no earlier than 2006-06-02 | C4 | 11919.2h |  | 1646 | Rel-7 | EMC1 | 29.060 | Mr Atle Monrad, Ericsson | Atle.Monrad@eto.ericsson.se |  |  | CCaR |  |
| 23 | 7 | **DELETE - PS domain and IMS support for IMS Emergency sessions** | 185d? | 2005-10-10 | 2006-06-23 |  |  | 2005-10-10 | 2006-06-23 | 185d? | 150d |  | S2 | 1940.97h |  |  | Rel-7 | IMS-EMER | 23.867, TS 23.abc, 23.060, 23.002, 23.271 | Curt Wong (Nokia) | curt.c.wong@nokia.com |  | Maurice |  | SP-30 |
| 24 | 7.1 | DELETE IMS aspects to support IMS Emergency sessions | 121.31d? | 2005-10-10 | 2006-06-23 |  |  | 2005-10-10 | 2006-06-23 | 121.31d? | 150d | finish no earlier than 2006-06-23 | S2 | 970.48h |  |  | Rel-7 | IMS-EMER | 23.867, TS 23.abc, 23.060, 23.002, 23.271 | Curt Wong (Nokia) | curt.c.wong@nokia.com | TSG | Maurice |  | SP-30 |
| 25 | 7.2 | DELETE PS domain aspects to support IMS Emergency sessions | 121.31d? | 2005-10-10 | 2006-06-23 |  |  | 2005-10-10 | 2006-06-23 | 121.31d? | 150d | finish no earlier than 2006-06-23 | S2 | 970.48h |  |  | Rel-7 | IMS-EMER | 23.867, TS 23.abc, 23.060, 23.002, 23.271 | Curt Wong (Nokia) | curt.c.wong@nokia.com | TSG | Maurice |  | SP-30 |

Notes:
- 23: Approved at SP#29
- 24: Approved at SP#29
- 25: Approved at SP#29

| ID | WBS | Task | Type | Duration | Start | Finish | Complete | Remaining | Baseline start | Baseline finish | Baseline duration | Total slack | Constraint | Resources | Work | Actual work | Text1 | Text6 | Text7 | Text8 | Text12 | Text5 |
| --- | --- | --- | --- | --- | --- | --- | --- | --- | --- | --- | --- | --- | --- | --- | --- | --- | --- | --- | --- | --- | --- | --- |
| 26 | 8 | **Access Class Barring and Overload Protection** |  | 440d? | 2004-03-15 A | 2005-11-18 | 38% | 270.77d? | 2004-03-15 | 2005-11-18 | 440d? | 305d |  | S2 | 9240h | 3553.84h | ACBOP | Rel-7 | TSG | Maurice |  |  |
| 27 | 8.1 | TR on Stage 2 |  | 274d? | 2004-03-15 A | 2005-03-31 A | 100% |  | 2004-03-15 | 2005-03-31 | 274d? |  | finish no earlier than 2005-03-31 | S2 | 2192h | 2192h | ACBOP | Rel-7 | TSG |  |  |  |
| 28 | 8.2 | Extra ACBOP information in GERAN |  | 440d? | 2004-03-15 | 2005-11-18 |  |  | 2004-03-15 | 2005-11-18 | 440d? | 305d | finish no earlier than 2005-11-18 | GP | 3520h |  | ACBOP | Rel-7 | TSG | Gert |  |  |
| 29 | 8.3 | Stage 3 CN aspects of ACBOP |  | 1d? | 2004-12-08 A | 2004-12-08 A | 100% |  | 2004-12-08 | 2004-12-08 | 1d? |  | finish no earlier than 2004-12-08 | C1 | 8h | 8h | ACBOP | Rel-7 |  |  |  |  |
| 30 | 8.4 | Deleted - Potential impact on Iu interface Overload functionality | milestone | 0d? | 2004-03-15 A | 2004-03-15 A | 100% |  | 2004-03-15 | 2004-03-15 | 0d? |  | finish no earlier than 2004-03-15 | RP |  |  | ACBOP | Rel-7 |  |  | RP-25 |  |
| 31 | 8.5 | Deleted - Extra ACBOP information in RAN | milestone | 0d? | 2004-03-15 A | 2004-03-15 A | 100% |  | 2004-03-15 | 2004-03-15 | 0d? |  | finish no earlier than 2004-03-15 | RP |  |  | ACBOP | Rel-7 |  |  | RP-25 |  |
| 32 | 9 | **USSD message delivery and transfer to USIM** |  | 376d? | 2004-03-05 A | 2005-08-12 A | 100% |  | 2004-03-05 | 2005-11-16 | 443.7d? |  |  | S1 | 5698.4h | 5698.4h | USSD-USIM | Rel-7 | TSG | Michael |  |  |
| 33 | 9.1 | Stage 1 |  | 152d? | 2004-03-18 A | 2004-10-15 A | 100% |  | 2004-03-18 | 2004-10-15 | 152d? |  | start no earlier than 2004-03-18 | S1 | 1216h | 1216h | USSD-USIM | Rel-7 | TSG | Michael |  |  |
| 34 | 9.2 | Alignment with requirements regarding USSD usage |  | 193.3d? | 2004-03-05 A | 2005-08-12 A | 100% |  | 2004-03-05 | 2005-11-16 | 261d? |  | finish no earlier than 2005-08-12 | C6 | 1546.4h | 1546.4h | USSD-USIM | Rel-7 | TSG |  |  | cdubois@axalto.com |
| 35 | 10 | **Location Services enhancements Rel-7** |  | 565d? | 2004-06-28 A | 2006-08-25 | 50% | 283.84d? | 2004-06-28 | 2006-08-25 | 565d? | 105d |  | S2 | 26932.4h | 12012.2h | LCS3 | Rel-7 |  | Maurice |  |  |
| 36 | 10.1 | Global Stage 2 for LCS3 |  | 321d? | 2004-12-31 A | 2006-03-24 | 55% | 144.45d? | 2004-12-31 | 2006-03-24 | 321d? | 215d | finish no earlier than 2006-03-24 | S2 | 2568h | 1412.4h | LCS3 | Rel-7 | TSG | Maurice |  | brodilitz@sirf.com |
| 37 | 10.2 | **LCS for 3GPP Interworking WLAN** |  | 565d? | 2004-06-28 A | 2006-08-25 | 74% | 145.63d? | 2004-06-28 | 2006-08-25 | 565d? | 105d |  | S1 | 7148.37h | 2049.27h | LCS3-IWLAN | Rel-7 | TSG | Michael |  |  |
| 38 | 10.2.1 | FS on 3GPP system to WLAN Interworking with LCS |  | 316.7d? | 2004-06-28 A | 2005-09-29 | 77% | 72.84d? | 2004-06-28 | 2005-09-29 | 316.7d? | 341d | finish no earlier than 2005-09-29 | S1 | 2533.6h | 1950.87h | LCS3-IWLAN | Rel-7 |  |  |  |  |
| 39 | 10.2.2 | Stage 2 work on an LCS architecture for I-WLAN. |  | 11.85d? | 2005-10-10 A | 2006-08-25 |  | 11.85d? | 2005-10-10 | 2006-08-25 | 11.85d? | 0d | finish no earlier than 2006-08-25 | S2 | 94.77h |  | LCS3-IWLAN | Rel-7 |  | Maurice |  | dhshim@lge.com ; phede@lge.com |
| 40 | 10.3 | **UE positioning Rel-7** |  | 457d? | 2004-09-15 A | 2006-06-15 | 55% | 204.16d? | 2004-09-15 | 2006-06-15 | 456d? | 156d |  | RP | 9936h | 6025.24h | LCS3-UEpos | Rel-7 | TSG | Cesar |  |  |
| 41 | 10.3.1 | Inclusion of Uplink TDOA UE positioning method in the UTRAN specifications |  | 456d? | 2004-09-15 A | 2006-06-15 | 80% | 91.2d? | 2004-09-15 | 2006-06-15 | 456d? | 157d | finish no earlier than 2006-06-15 | R2 | 3648h | 2918.4h | LCS3-UEPos-UTDOA | Rel-7 | TSG | MCC_RAN |  | rlgross@trueposition.com |
| 42 | 10.3.2 | Global Navigation Satellite System (GNSS) in UTRAN |  | 131d? | 2005-12-15 | 2006-06-15 |  |  |  |  |  | 156d | finish no earlier than 2006-06-15 | R2 | 1048h |  |  | Rel-7 |  | MCC_RAN |  | alain.abinakhoul@francetelecom.com |
| 43 | 10.3.3 | **LCS Enhancements Related to Location-Based Services** |  | 66d? | 2005-03-15 A | 2005-06-15 | 25% | 49.5d? | 2005-03-15 | 2005-06-15 | 66d? | 418d |  | R2 | 1584h | 396h | LCS3-UEPos-LBS | Rel-7 | TSG | MCC_RAN |  | BRodilitz@SiRF.com |
| 44 | 10.3.3.1 | RAN2 aspects for LBS |  | 66d? | 2005-03-15 A | 2005-06-15 | 50% | 33d? | 2005-03-15 | 2005-06-15 | 66d? | 418d | finish no earlier than 2005-06-15 | R2 | 528h | 264h | LCS3-UEPos-LBS | Rel-7 | TSG | MCC_RAN |  | BRodilitz@SiRF.com |
| 45 | 10.3.3.2 | CT4 aspects for LBS |  | 66d? | 2005-03-15 | 2005-06-15 |  |  | 2005-03-15 | 2005-06-15 | 66d? | 418d | finish no earlier than 2005-06-15 | C4 | 528h |  | LCS3-UEPos-LBS | Rel-7 | TSG |  |  |  |
| 46 | 10.4 | LCS Enhancements Related to Location-Based Services |  | 345d? | 2005-01-03 A | 2006-04-28 | 10% | 310.5d? | 2005-01-03 | 2006-04-07 | 330d? | 190d | finish no earlier than 2006-04-28 | GP | 2760h | 276h | LCS3-LBS | Rel-7 | TSG | Paolo |  | kjudge@sirf.com |
| 47 | 11 | **Advanced Global Navigation Satellite System (A-GNSS) concept** |  | 470d? | 2004-06-28 A | 2006-04-14 | 20% | 373.72d? | 2004-06-28 | 2006-04-14 | 470d? | 200d |  | S1 | 9649.6h | 1356.88h | LCS3-AGNSS | Rel-7 | TSG | Michael |  | Michel.monnerat@space.alcatel.fr |
| 48 | 11.1 | Support for GNSS in GERAN |  | 451.2d? | 2004-06-28 A | 2006-04-14 | 5% | 428.64d? | 2004-06-28 | 2006-04-14 | 451.2d? | 200d | finish no earlier than 2006-04-14 | GP | 3609.6h | 180.48h | AGNSS-GP | Rel-7 | TSG | Paolo |  | richard.couty@space.alcatel.fr |
| 49 | 11.2 | Towards A-GNSS Concept |  | 285d? | 2004-08-27 A | 2005-09-29 | 45% | 156.75d? | 2004-08-27 | 2005-09-29 | 285d? | 341d | finish no earlier than 2005-09-29 | S1 | 2280h | 1026h | GNSS | Rel-7 | TSG | Paolo |  | richard.couty@space.alcatel.fr |

Notes:
- 26: Text3: 23.898 / Text4: Chris Pudney, Vodafone
- 28: Text3: 44.018
- 29: NEW - inserted on 2/9/2004
- 30: Text3: 25.413
- 31: Text3: 25.331
- 32: Text3: 22.090
- 33: Text3: 22.090
- 34: Text4: Christophe Dubois (Axalto)
- 35: Text3: 23.271
- 36: Approved SA#27. Appropriate place forEmergency work to be found / Text3: 23.271 / Text4: Ben Rodilitz, SiRF
- 37: Text3: 22.935 / Text4: Mike Loushine, (Telcordia)
- 38: DAB - Should be SA1 / Text3: 22.935
- 39: Approved in SP#29 / Text3: 23.8yz / Text4: Donghee Shim (LG Electronics Inc.); Patrice HÉDÉ (LG Electronics Mobilecomm France)
- 41: Text3: TS25.305, TS25.453 / Text4: Robert Gross, TruePosition
- 42: Text3: TS 25.305,TS 25.331,TS 25.306,TS 25.413,TS 25.423,TS 25.433,TS 25.453,TS 25.171,TS 34.171 / Text4: Alain Abinakhoul, France Telecom
- 43: Text3: 25.305, 25.331, 25.410, 25.413, 25.453 / Text4: Ben Rodilitz
- 44: Text3: 25.305, 25.331, 25.410, 25.413, 25.453 / Text4: Ben Rodilitz
- 45: Reminded by e-mail from Hannu on 19/12/05
- 46: Linked SP-040682 / Text3: 43.059, 44.031, 48.008, 49.031 / Text4: Kevin Judge, SiRF Technologies
- 47: Text4: Michel MONNERAT
- 48: Started / Text4: Richard Couty, ALCATEL SA
- 49: Text4: Richard Couty, ALCATEL SA

| ID | WBS | Task | Type | Duration | Start | Finish | Complete | Remaining | Baseline start | Baseline finish | Baseline duration | Total slack | Constraint | Resources | Work | Actual work | Text1 | Text4 | Text5 | Text6 | Text7 | Text8 |
| --- | --- | --- | --- | --- | --- | --- | --- | --- | --- | --- | --- | --- | --- | --- | --- | --- | --- | --- | --- | --- | --- | --- |
| 50 | 12 | **Combinational Services** |  | 296d? | 2005-01-17 A | 2006-03-06 | 92% | 22.24d? | 2005-01-17 | 2005-12-07 | 233d? | 229d |  | S1 | 7544h | 6977.09h | CSICS | Robert Frank, TeliaSonera | Robert.Frank@teliasonera.com | Rel-7 | TSG | Michael |
| 51 | 12.1 | Stage 1 for CSICS |  | 104d? | 2005-01-17 A | 2005-06-09 A | 100% |  | 2005-01-17 | 2005-06-09 | 104d? |  | start no earlier than 2005-01-17 | S1 | 832h | 832h | CSICS |  |  | Rel-7 | TSG |  |
| 52 | 12.2 | Stage 2 for CSICS |  | 130d? | 2005-01-17 A | 2005-07-15 A | 100% |  | 2005-01-17 | 2005-07-15 | 130d? |  | start no earlier than 2005-01-17 | S2 | 1040h | 1040h | CSICS |  |  | Rel-7 |  |  |
| 53 | 12.3 | Stage 3 for CSICS CN aspects |  | 221d? | 2005-05-02 A | 2006-03-06 | 78% | 48.62d? | 2005-05-02 | 2005-10-28 | 130d? | 229d | finish no earlier than 2006-03-06 | C1 | 1768h | 1379.04h | CSICS | Peter Dawes (Vodafone) |  | Rel-7 | TSG | Andrijana |
| 54 | 12.4 | Stage 3 for codec aspects |  | 192d? | 2005-03-15 A | 2005-12-07 A | 100% |  | 2005-03-15 | 2005-12-07 | 192d? |  | finish no earlier than 2005-12-07 | S4 | 1536h | 1536h | CSICS-Codec | Per Fröjdh, Ericsson | Per.Frojdh@ericsson.com | Rel-7 | TSG | Paolo |
| 55 | 13 | **All-IP Network (AIPN)** |  | 448d? | 2004-06-28 A | 2006-03-15 A | 100% |  | 2004-06-28 | 2006-03-15 | 448d? |  |  | S1 | 8672h | 8672h | AIPN | Chris Sachno (NTT DoCoMo) | c.masyu@nttdocomo.co.jp | Rel-7 | TSG | Michael |
| 56 | 13.1 | All-IP Network Feasibility Study |  | 188d? | 2004-06-28 A | 2005-03-16 A | 100% |  | 2004-06-28 | 2005-03-16 | 188d? |  | start no earlier than 2004-06-28 | S1 | 1504h | 1504h | AIPFS | Chris Sachno (NTT DoCoMo) | c.masyu@nttdocomo.co.jp | Rel-7 | TSG | Michael |
| 57 | 13.2 | Stage1 |  | 448d? | 2004-06-28 A | 2006-03-15 A | 100% |  | 2004-06-28 | 2006-03-15 | 448d? |  | finish no earlier than 2006-03-15 | S1 | 3584h | 3584h | AIPN | Chris Sachno (NTT DoCoMo) | c.masyu@nttdocomo.co.jp | Rel-7 | TSG | Michael |
| 58 | 14 | Enhancement of E2E QoS |  | 336.4d? | 2004-06-28 A | 2005-12-01 A | 100% |  | 2004-06-28 | 2005-12-01 | 336.4d? |  | finish no earlier than 2005-12-01 | S2 | 2691.2h | 2691.2h | QoS7 |  |  | Rel-7 | TSG | Maurice |
| 59 | 15 | **System enhancements for fixed broadband access to IMS** |  | 611d? | 2003-11-05 A | 2006-03-08 | 62% | 234.14d? | 2004-08-03 | 2005-12-08 | 353d? | 227d |  | S2 | 16753.6h | 10240.7h | FBI |  |  | Rel-7 | TSG | Maurice |
| 60 | 15.1 | Stage 2 |  | 365d? | 2004-10-14 A | 2006-03-08 | 75% | 91.25d? | 2004-10-14 | 2005-12-08 | 301d? | 227d | finish no earlier than 2006-03-08 | S2 | 2920h | 2190h | FBI |  |  | Rel-7 | TSG | Maurice |
| 61 | 15.2 | **Protocol impact from providing IMS services via fixed broadband** |  | 541d? | 2003-11-05 A | 2005-11-30 | 58% | 225.42d? | 2004-08-03 | 2005-11-30 | 347d? | 297d |  | C1 | 11104h | 6477.33h | FBI | Peter Leis (Siemens) |  | Rel-7 | TSG | Andrijana |
| 62 | 15.2.1 | CT1 aspects of FBI |  | 347d? | 2004-08-03 A | 2005-11-30 | 85% | 52.05d? | 2004-08-03 | 2005-11-30 | 347d? | 297d | finish no earlier than 2005-03-03 | C1 | 2776h | 2359.6h | FBI | Siemens |  | Rel-7 | TSG | Andrijana |
| 63 | 15.2.2 | CT3 aspects of FBI |  | 347d? | 2003-11-05 A | 2005-03-03 | 90% | 34.7d? | 2004-08-03 | 2005-11-30 | 347d? | 491d | finish no earlier than 2005-03-03 | C3 | 2776h | 2498.4h | FBI | Siemens |  | Rel-7 | TSG | Andrijana |
| 64 | 15.2.3 | CT4 aspects of FBI |  | 347d? | 2003-11-05 | 2005-03-03 |  |  | 2004-08-03 | 2005-11-30 | 347d? | 491d | finish no earlier than 2005-03-03 | C4 | 2776h |  | FBI | Siemens |  | Rel-7 | TSG | Andrijana |
| 65 | 15.3 | Security Enhancements for Fixed Broadband Access to IMS |  | 118d? | 2005-06-28 A | 2005-12-08 | 50% | 59d? | 2005-06-28 | 2005-12-08 | 118d? | 291d | start no earlier than 2005-06-28 | S3 | 944h | 472h | FBI-ISE | Bengt Sahlin, Ericsson | Bengt.Sahlin@ericsson.com | Rel-7 |  | Mike |
| 66 | 16 | Access Security Enhancements |  | 195d? | 2005-01-03 A | 2005-09-30 | 30% | 136.5d? | 2005-01-03 | 2005-09-30 | 195d? | 340d | finish no earlier than 2005-09-30 | S3 | 1560h | 468h | ACCSEC2 | Bengt Sahlin, Ericsson | Bengt.Sahlin@ericsson.com | Rel-7 | TSG | Michael |
| 67 | 17 | **Mp (MRFC - MRFP) interface** |  | 644d | 2002-12-13 | 2005-06-01 |  |  | 2002-12-13 | 2005-06-01 | 644d | 427d |  | C4 | 20608h |  | Mp | Emmanuel Gay (Orange) |  | Rel-7 |  |  |
| 68 | 17.1 | CT1 aspects of Mp |  | 644d | 2002-12-13 | 2005-06-01 |  |  | 2002-12-13 | 2005-06-01 | 644d | 427d | finish no earlier than 2005-06-01 | C1 | 5152h |  | Mp | Orange |  | Rel-7 |  |  |
| 69 | 17.2 | CT3 aspects of Mp |  | 644d | 2002-12-13 | 2005-06-01 |  |  | 2002-12-13 | 2005-06-01 | 644d | 427d | finish no earlier than 2005-06-01 | C3 | 5152h |  | Mp | Orange |  | Rel-7 |  |  |
| 70 | 17.3 | CT4 aspects of Mp |  | 644d | 2002-12-13 | 2005-06-01 |  |  | 2002-12-13 | 2005-06-01 | 644d | 427d | finish no earlier than 2005-06-01 | C4 | 5152h |  | Mp | Orange |  | Rel-7 |  |  |
| 71 | 18 | IMS Stage 3 IETF Protocol alignment |  | 261d? | 2004-12-10 A | 2005-12-09 | 40% | 156.6d? | 2004-12-10 | 2005-12-09 | 261d? | 290d | finish no earlier than 2005-12-09 | C1 | 2088h | 835.2h | IMSProtoc |  |  | Rel-7 |  |  |
| 72 | 19 | **Rel-7 Improvements of the Radio Interface** |  | 588d? | 2004-09-15 A | 2006-12-15 | 60% | 233.05d? | 2004-09-15 | 2006-06-15 | 456d? | 25d |  | RP | 19832h | 11184.3h | RInImp |  |  | Rel-7 |  | Cesar |
| 73 | 19.1 | UMTS 2.6 GHz |  | 195d? | 2004-09-15 A | 2005-06-14 A | 100% |  | 2004-09-15 | 2005-06-14 | 195d? |  | finish no earlier than 2005-06-14 | R4 | 1560h | 1560h | RInImp-UMTS2600 | Jussi Numminen, Nokia | jussi.numminen@nokia.com | Rel-7 | TSG | Cesar |
| 74 | 19.2 | UMTS 2.6 GHz TDD |  | 261d? | 2004-12-15 A | 2005-12-14 A | 100% |  | 2004-12-15 | 2005-12-15 | 261d? |  | finish no earlier than 2005-12-15 | R4 | 2088h | 2088h | RInImp-UMTS2600TDD | Shin Horng Wong (IPWireless) | shwong@IPWIRELESS.COM | Rel-7 | TSG | MCC_RAN |
| 75 | 19.3 | UMTS 900 MHz |  | 261d? | 2004-12-15 A | 2005-12-14 A | 100% |  | 2004-12-15 | 2005-12-15 | 261d? |  | finish no earlier than 2005-12-15 | R4 | 2088h | 2088h | RInImp-UMTS900 | Yannick Li (Nortel) | yli@nortelnetworks.com | Rel-7 | TSG | MCC_RAN |
| 76 | 19.4 | UMTS 1700 MHz |  | 197d? | 2005-03-15 A | 2005-12-14 A | 100% |  | 2005-03-15 | 2005-12-15 | 197d? |  | finish no earlier than 2005-12-15 | R4 | 1576h | 1576h | RInImp-UMTS1700 | Takehiro Nakamura | NTT DoCoMo | Rel-7 | TSG | MCC_RAN |
| 77 | 19.5 | Pending decision of the PCG!! UMTS 2.6 GHz FDD DL External |  | 195d? | 2005-09-15 | 2006-06-15 |  |  | 2005-09-15 | 2006-06-15 | 195d? | 157d | finish no earlier than 2006-06-15 | R4 | 1560h |  | RInImp-UMTS2600Ext | Han van Bussel | han.van.bussel@t-mobile.de | Rel-7 | TSG | MCC_RAN |
| 78 | 19.6 | UE Antenna Performance Evaluation Method and Requirements |  | 325d? | 2004-12-15 A | 2006-03-15 | 55% | 146.25d? | 2004-12-15 | 2006-03-15 | 325d? | 223d | finish no earlier than 2006-03-15 | R4 | 2600h | 1430h | RInImp-UEAnt | Christian Bergljung (TeliaSonera) | Christian.Bergljung@TeliaSonera.com | Rel-7 | TSG | MCC_RAN |
| 79 | 19.7 | Improved Performance Requirements for HSDPA UE based on Rx Diversity (type 1) & LMMSE equalizer (type 2) | milestone | 0d? | 2005-03-15 A | 2005-03-15 | 50% | 0d? | 2005-03-15 | 2005-03-15 | 0d? | 484d | finish no earlier than 2005-03-15 | R4 |  |  | RInImp-HSPerf-Type3 | Marc Grant | marc.grant@cingular.com | Rel-7 | TSG | MCC_RAN |
| 80 | 19.8 | Improved Performance Requirements for non-HSDPA channels based on Enhanced Receiver, Type 1 (Rx Diversity) |  | 195d? | 2005-09-15 A | 2006-06-15 | 25% | 146.25d? | 2005-09-15 | 2006-06-15 | 195d? | 157d | finish no earlier than 2006-06-15 | R4 | 1560h | 390h | RInImp-DCHPerf-RxDiv | Marc Grant | marc.grant@cingular.com | Rel-7 | TSG | MCC_RAN |
| 81 | 19.9 | Improved support of gaming over HSDPA/EDCH |  | 262d? | 2005-12-15 | 2006-12-15 |  |  |  |  |  | 25d | finish no earlier than 2006-12-15 | R2 | 2096h |  | RInImp-Gaming | Don Zelmer, Cingular | don.zelmer@cingular.com | Rel-7 |  | MCC_RAN |

Notes:
- 51: Text3: 22.279
- 52: Text3: 23.279
- 53: Text3: 24.229, 24.008
- 54: Started / Text3: TS 26.141, 26.235, 26.236
- 55: Text3: 22.978
- 56: Text3: 22.978
- 57: Text3: 22.258
- 58: DAB - pushed back to June / Text3: 23.802
- 61: Text3: new TR 24.819, 24.229, 29.229, 29.163, 29.209
- 62: Text3: new TR 24.819, 24.229, 29.229, 29.163, 29.209
- 63: Text3: new TR, 29.229, 29.163
- 64: Text3: 29.209
- 65: Duplicated entry ("ACCSEC2", "Access Security Enhancements", SP-040865) deleted by A.Sultan / Text3: 33.102, 43.020
- 66: WID approved SA#26. Record created after SA#27. It is about improved GERAN security / Text3: 33.102, 43.020
- 68: Text3: 24.229
- 69: Text3: 29.162
- 70: Text3: 29.333
- 73: Approved at RP#25 as RP-040377 / Text3: TS25.101, TS25.104, TS25.133, TS25.141, TS25.331, TS25.942, TS25.306, TS25.307, TS34.121
- 74: Text3: 25.102, 25.105, 25.113, 25.123, 25.142, 25.331, 25.942, 25.306, 25.307, 34.122, 34.124
- 75: Text3: 25.101, 25.104, 25.113, 25.133, 25.141, 25.331, 25.942, 25.306, 25.307, 34.121
- 76: Text3: 25.101, 25.104, 25.113, 25.133, 25.141, 25.306, 25.307, 25.331, 34.121
- 77: Text3: 25.101, 25.104, 25.133, 25.141, 25.331, 25.942, 25.306, 25.307, 34.121
- 78: Text3: TS25.101
- 79: Text3: 25.101
- 80: Text3: 25.101

| ID | WBS | Task | Duration | Start | Finish | Complete | Remaining | Baseline start | Baseline finish | Baseline duration | Total slack | Constraint | Resources | Work | Actual work | Text1 | Text4 | Text5 | Text6 | Text7 | Text8 |
| --- | --- | --- | --- | --- | --- | --- | --- | --- | --- | --- | --- | --- | --- | --- | --- | --- | --- | --- | --- | --- | --- |
| 82 | 20 | **7.68Mcps TDD option** | 391d? | 2004-09-15 A | 2006-03-15 | 68% | 125.12d? | 2004-09-15 | 2006-06-15 | 456d? | 222d |  | RP | 18768h | 12013.4h | VHCRTDD | Martin Beale, IPWireless | mbeale@ipwireless.com | Rel-7 | TSG | Cesar |
| 83 | 20.1 | VHCRTDD: Stage 2 | 391d? | 2004-09-15 A | 2006-03-15 | 90% | 39.1d? | 2004-09-15 | 2005-12-15 | 326d? | 222d | finish no earlier than 2006-03-15 | R1 | 3128h | 2815.2h | VHCRTDD-Stage2 | Martin Beale, IPWireless | mbeale@ipwireless.com | Rel-7 | TSG | MCC_RAN |
| 84 | 20.2 | VHCRTDD: Physical Layer | 391d? | 2004-09-15 A | 2006-03-15 | 90% | 39.1d? | 2004-09-15 | 2005-12-15 | 326d? | 222d | finish no earlier than 2006-03-15 | R1 | 3128h | 2815.2h | VHCRTDD-Phys | Martin Beale, IPWireless | mbeale@ipwireless.com | Rel-7 | TSG | MCC_RAN |
| 85 | 20.3 | VHCRTDD: Layer 2 and layer 3 protocol aspects | 391d? | 2004-09-15 A | 2006-03-15 | 50% | 195.5d? | 2004-09-15 | 2005-12-15 | 326d? | 222d | finish no earlier than 2006-03-15 | R2 | 3128h | 1564h | VHCRTDD-L23 | Derek Richards, IPWireless | drichards@ipwireless.com | Rel-7 | TSG | MCC_RAN |
| 86 | 20.4 | VHCRTDD: UTRAN Iub/Iur Protocol Aspects | 391d? | 2004-09-15 A | 2006-03-15 | 50% | 195.5d? | 2004-09-15 | 2005-12-15 | 326d? | 222d | finish no earlier than 2006-03-15 | R3 | 3128h | 1564h | VHCRTDD-IurIub | Peter Legg, IPWireless | plegg@ipwireless.com | Rel-7 | TSG | MCC_RAN |
| 87 | 20.5 | VHCRTDD: RF Radio Transmission/ Reception, System Performance Requirements and Conformance Testing | 391d? | 2004-09-15 A | 2006-03-15 | 60% | 156.4d? | 2004-09-15 | 2006-06-15 | 456d? | 222d | finish no earlier than 2006-03-15 | R4 | 3128h | 1876.8h | VHCRTDD-RF | Shin Horng Wong | shwong@ipwireless.com | Rel-7 | TSG | MCC_RAN |
| 88 | 21 | **Rel-7 RAN improvements** | 392d? | 2004-12-15 A | 2006-06-15 | 45% | 214.66d? | 2004-12-15 | 2006-03-15 | 325d? | 156d |  | RP | 11000h | 4250.05h | RANimp |  |  | Rel-7 | TSG | Cesar |
| 89 | 21.1 | Optimisation of channelisation code utilisation for 1.28 Mcps TDD | 326d? | 2004-12-15 A | 2006-03-15 | 70% | 97.8d? | 2004-12-15 | 2005-12-15 | 261d? | 222d | finish no earlier than 2006-03-15 | R1 | 2608h | 1825.6h | RANimp-RABSE-CodOptLCRTDD | Ka Leong Lo | kaleong.lo@utstar.com | Rel-7 | TSG | MCC_RAN |
| 90 | 21.2 | Delay optimisation for procedures applicable to CS and PS Connections | 328d? | 2005-03-15 A | 2006-06-15 | 20% | 262.4d? | 2005-03-15 | 2006-03-15 | 261d? | 156d | finish no earlier than 2006-06-15 | R2 | 2624h | 524.8h | RANimp-DelayOpt | Juho Pirskanen | juho.pirskanen@nokia.com | Rel-7 | TSG | MCC_RAN |
| 91 | 21.3 | UE Performance Requirements for MBMS (TDD) | 261d? | 2005-03-15 A | 2006-03-15 | 50% | 130.5d? | 2005-03-15 | 2006-03-15 | 261d? | 223d | finish no earlier than 2006-03-15 | R4 | 2088h | 1044h | MBMS-RAN-RF-TDD | Shin Horng Wong | shwong@ipwireless.com | Rel-7 | TSG | MCC_RAN |
| 92 | 21.4 | Continuous connectivity for packet data users | 68d? | 2005-03-14 A | 2005-06-15 | 30% | 47.6d? | 2005-03-14 | 2005-03-15 | 1d? | 417d | finish no earlier than 2005-06-15 | R1 | 544h | 163.2h | RANimp-CoCoPack | Joerg Gustrau | joerg.gustrau@siemens.com | Rel-7 | TSG | MCC_RAN |
| 93 | 22 | **3.84 Mcps TDD Enhanced Uplink** | 327d? | 2005-03-15 A | 2006-06-15 | 41% | 194.56d? | 2005-03-15 | 2006-06-15 | 327d? | 157d |  | RP | 13072h | 4666.03h | EDCHTDD | Nicholas Anderson | nanderson@ipwireless.com | Rel-7 | TSG | Cesar |
| 94 | 22.1 | EDCHTDD: Stage 2 | 197d? | 2005-03-15 A | 2005-12-14 | 60% | 78.8d? | 2005-03-15 | 2005-12-14 | 197d? | 287d | start no earlier than 2005-03-15 | R2 | 1576h | 945.6h | EDCHTDD-Stage2 | Nicholas Anderson | nanderson@ipwireless.com | Rel-7 | TSG | MCC_RAN |
| 95 | 22.2 | EDCHTDD: Physical Layer | 261d? | 2005-03-15 A | 2006-03-14 | 60% | 104.4d? | 2005-03-15 | 2006-03-14 | 261d? | 223d | start no earlier than 2005-03-15 | R1 | 2088h | 1252.8h | EDCHTDD-Phys | Nicholas Anderson | nanderson@ipwireless.com | Rel-7 | TSG | MCC_RAN |
| 96 | 22.3 | EDCHTDD: Layer 2 and 3 Protocol Aspects | 261d? | 2005-03-15 A | 2006-03-14 | 60% | 104.4d? | 2005-03-15 | 2006-03-14 | 261d? | 223d | start no earlier than 2005-03-15 | R2 | 2088h | 1252.8h | EDCHTDD-L23 | Derek Richards | drichards@ipwireless.com | Rel-7 | TSG | MCC_RAN |
| 97 | 22.4 | EDCHTDD: UTRAN Iub/Iur Protocol Aspects | 261d? | 2005-03-15 A | 2006-03-14 | 25% | 195.75d? | 2005-03-15 | 2006-03-14 | 261d? | 223d | start no earlier than 2005-03-15 | R3 | 2088h | 522h | EDCHTDD-IurIub | Jim Miller | jim.miller@interdigital.com | Rel-7 | TSG | MCC_RAN |
| 98 | 22.5 | EDCHTDD: RF Radio Transmission/ Reception, System Performance Requirements and Conformance Testing | 327d? | 2005-03-15 A | 2006-06-15 | 10% | 294.3d? | 2005-03-15 | 2006-06-15 | 327d? | 157d | finish no earlier than 2006-06-15 | R4 | 2616h | 261.6h | EDCHTDD-RF | Shin Horng Wong | shwong@ipwireless.com | Rel-7 | TSG | MCC_RAN |
| 99 | 23 | **Support of SMS and MMS over generic 3GPP IP access** | 432d? | 2004-10-14 A | 2006-06-09 | 73% | 117.26d? | 2004-10-14 | 2006-06-09 | 432d? | 160d |  | S2 | 6944h | 3717.6h | SMSIP | Wenlin Zhang (Huawei) | zhangwenlin@huawei.com | Rel-7 | TSG | Maurice |
| 100 | 23.1 | FS on SMSIP | 173d? | 2004-10-14 A | 2005-06-13 A | 100% |  | 2004-10-14 | 2005-06-13 | 173d? |  | start no earlier than 2004-10-14 | S2 | 1384h | 1384h | SMSIP |  |  | Rel-7 |  |  |
| 101 | 23.2 | Stage 2 for SMSIP | 263d? | 2005-06-08 A | 2006-06-09 | 55% | 118.35d? | 2005-06-08 | 2006-06-09 | 263d? | 160d | start no earlier than 2005-06-08 | S2 | 2104h | 1157.2h | SMSIP |  |  | Rel-7 |  |  |
| 102 | 24 | **Evolution of Policy Control and Charging** | 507d? | 2004-10-14 A | 2006-09-22 | 31% | 347.3d? | 2004-10-14 | 2006-06-16 | 437d? | 85d |  | S2 | 14992h | 4722.43h | PCC |  |  | Rel-7 | TSG | Maurice |
| 103 | 24.1 | TR for PCC | 315d? | 2004-10-14 A | 2005-12-29 A | 100% |  | 2004-10-14 | 2005-12-29 | 315d? |  | finish no earlier than 2005-12-28 | S2 | 2520h | 2520h | PCC |  |  | Rel-7 |  |  |
| 104 | 24.2 | Stage 2 for PCC | 315d? | 2005-07-04 A | 2006-09-15 | 30% | 220.5d? | 2005-07-04 | 2006-06-16 | 250d? | 90d | finish no earlier than 2006-09-15 | S2 | 2520h | 756h | PCC |  |  | Rel-7 |  |  |
| 105 | 24.3 | Evolution of policy control and flow based bearer level charging | 315d? | 2005-07-04 | 2006-09-15 |  |  | 2005-07-04 | 2006-06-16 | 250d? | 90d | finish no earlier than 2006-09-15 | S2 | 2520h |  | PCC | Balazs Bertenyi (Nokia) | balazs.bertenyi@nokia.com | Rel-7 |  |  |
| 106 | 24.4 | Gx reference point for Policy and Charging Control | 211d? | 2005-12-02 A | 2006-09-22 | 5% | 200.45d? |  |  |  | 85d | start no earlier than 2005-12-02 | C3 | 1688h | 84.4h | PCC | Thomas Belling (Siemens) | thomas.belling@siemens.com | Rel-7 |  | Seung Don |
| 107 | 24.5 | Rx reference point for Policy and Charging Control | 211d? | 2005-12-02 A | 2006-09-22 | 5% | 200.45d? |  |  |  | 85d | start no earlier than 2005-12-02 | C3 | 1688h | 84.4h | PCC | Javier Pastor (Ericsson) | j.javier.pastor@ericsson.com | Rel-7 |  | Seung Don |
| 108 | 25 | Video Codec Performance Requirements | 453d? | 2005-01-03 A | 2006-09-27 | 25% | 339.75d? | 2005-01-03 | 2006-09-27 | 453d? | 82d | finish no earlier than 2006-09-27 | S4 | 3624h | 906h | VICPer | Juergen Pandel (Siemens AG) | juergen.pandel@siemens.com | Rel-7 | TSG | Paolo |
| 109 | 26 | DIAMETER on the GGSN Gi interface | 531d? | 2004-09-10 | 2006-09-22 |  |  | 2004-09-10 | 2005-09-16 | 266d? | 85d | finish no earlier than 2006-09-22 | C3 | 4248h |  | DIAMGi |  |  | Rel-7 | TSG | Seung Don |

Notes:
- 82: Approved at RP#25 as RP-040365
- 83: Text3: New specification
- 84: Text3: TS25.221, TS25.222, TS25.223, TS25.224,TS25.225
- 85: Text3: TS25.301, TS25.302, TS25.305, TS25.306, TS25.321, TS25.331
- 86: Text3: TS25.401, TS25.420, TS25.423, TS25.425, TS25.427, TS25.430, TS25.433, TS25.435
- 87: Text3: TS25.102, TS25.105, TS25.123, TS25.133, TS25.142
- 88: Generic feature
- 90: Text3: TS25.321, TS25.322, TS25.331
- 91: Text3: TS25.102, TS25.123
- 95: Text3: TS25.201, TS25.221,TS25.222, TS25.223, TS25.224, TS25.225
- 96: Text3: TS25.301, TS25.302, TS25.306, TS25.321, TS25.331
- 97: Text3: TS25.401, TS25.420, TS25.423, TS25.427, TS25.430, TS25.433, TS25.435
- 98: Text3: TS25.102, TS25.105, TS25.123, TS25.142
- 99: Revised at SP#29 / Text3: TR 23.abc, TS 23.abc
- 100: Text3: 23.804
- 101: Text3: 23.204
- 104: Text3: 23.203
- 105: Approved at SP#29. 23.125 will be discontinued from Release 7. / Text3: 23.207, 23.125, 23.002, 23.228
- 106: Approved at CP#30 / Text3: 29.210, 29.207, 29.208
- 107: Approved at CP#30 / Text3: 29.209, 29.211
- 108: Text3: 26.234, 26.235, 26.346, 26.140
- 109: 13/12/2005 08:00 / Text3: 29.061

| ID | WBS | Task | Type | Duration | Start | Finish | Complete | Remaining | Baseline start | Baseline finish | Baseline duration | Total slack | Constraint | Resources | Work | Actual work | Text1 | Text4 | Text5 | Text6 | Text7 | Text8 |
| --- | --- | --- | --- | --- | --- | --- | --- | --- | --- | --- | --- | --- | --- | --- | --- | --- | --- | --- | --- | --- | --- | --- |
| 110 | 27 | **CAMEL Trunk Triggers** |  | 251d? | 2004-12-17 A | 2005-12-05 | 55% | 112.95d? | 2004-12-17 | 2005-12-05 | 251d? | 294.5d |  | S1 | 6024h | 3313.2h | TTCAMEL | Amar Deol, Nortel Networks | deola@nortelnetworks.com | Rel-7 | TSG | Michael |
| 111 | 27.1 | Stage 1 for CAMEL Trunk Triggers |  | 251d? | 2004-12-17 A | 2005-12-05 A | 100% |  | 2004-12-17 | 2005-12-05 | 251d? |  |  | S1 | 2008h | 2008h | TTCAMEL | Amar Deol, Nortel Networks | deola@nortelnetworks.com | Rel-7 | TSG | Michael |
| 112 | 27.2 | CAMEL Trunk Originated Trigger Detection Points |  | 251d? | 2004-12-17 A | 2005-12-05 | 10% | 225.9d? | 2004-12-17 | 2005-12-05 | 251d? | 294.5d | start no earlier than 2004-12-17 | C4 | 2008h | 200.8h | CamelR7 | David Hutton, Nortel Networks | dhutton@nortel.com | Rel-7 | TSG | Kimmo |
| 113 | 28 | MS Antenna Performance Evaluation Method and Requirements |  | 326d? | 2005-01-28 A | 2006-04-28 | 20% | 260.8d? | 2005-01-28 | 2005-11-11 | 206d? | 190d | finish no earlier than 2006-04-28 | G1 | 2608h | 521.6h | APEMR | Ulf.Tegth (TeliaSonera) | Ulf.Tegth@teliasonera.com | Rel-7 | TSG | Paolo |
| 114 | 29 | **Lower 700 MHz Inclusion in the GERAN Specifications** |  | 345d? | 2005-01-03 A | 2006-04-28 | 34% | 226d? | 2005-01-03 | 2006-04-28 | 345d? | 190d |  | GP | 6552h | 1901.6h | GSM710 | Dave Cotton (UTC) | dcotton@mtview.union-tel.com | Rel-7 | TSG | Paolo |
| 115 | 29.1 | Inclusion of the 698 – 746 MHz band into GERAN core specifications |  | 129d? | 2005-01-03 A | 2005-06-30 A | 100% |  | 2005-01-03 | 2005-06-30 | 129d? |  | finish no earlier than 2005-06-30 | G1 | 1032h | 1032h | GSM710-core |  |  | Rel-7 |  | Paolo |
| 116 | 29.2 | G1 aspects of Inclusion of the 698 – 746 MHz band into GERAN test specifications |  | 172.5d? | 2005-08-31 A | 2006-04-28 | 10% | 155.25d? | 2005-08-31 | 2006-04-28 | 172.5d? | 190d | start no earlier than 2005-08-31 | G1 | 1380h | 138h | GSM-710-test |  |  | Rel-7 |  | Stoyan |
| 117 | 29.3 | G3 aspects of Inclusion of the 698 – 746 MHz band into GERAN test specifications |  | 172.5d? | 2005-08-31 A | 2006-04-28 | 10% | 155.25d? |  |  |  | 190d | finish no earlier than 2006-04-28 | G3 | 1380h | 138h | GSM-710-test |  |  | Rel-7 |  | Stoyan |
| 118 | 30 | **Enhancements of VGCS for public authority officials** |  | 436d? | 2004-08-27 A | 2006-04-28 | 44% | 245.01d? | 2004-08-27 | 2005-12-06 | 333d? | 190d |  | S1 | 16600h | 5461.2h | EVGCS | Siemens |  | Rel-7 | TSG | Andrijana |
| 119 | 30.1 | Stage 1 | milestone | 0d? | 2004-08-27 A | 2004-08-27 A | 100% |  | 2004-08-27 | 2004-08-27 | 0d? |  | finish no earlier than 2004-08-27 | S1 |  |  | EVGCS | Joerg Swetina (Siemens AG) | joerg.swetina@SIEMENS.COM | Rel-7 | TSG | Michael |
| 120 | 30.2 | **Architecture and protocol aspects** |  | 401d? | 2004-08-27 A | 2006-03-10 | 35% | 260.65d? | 2004-08-27 | 2005-12-06 | 333d? | 225d |  | C1 | 9624h | 3368.4h | EVGCS | Robert Zaus (Siemens) |  | Rel-7 |  |  |
| 121 | 30.2.1 | CT1 aspects of EVGCS |  | 401d? | 2004-08-27 A | 2006-03-10 | 70% | 120.3d? | 2004-08-27 | 2005-12-06 | 333d? | 225d | finish no earlier than 2006-03-10 | C1 | 3208h | 2245.6h | EVGCS | Siemens |  | Rel-7 |  |  |
| 122 | 30.2.2 | CT4 aspects of EVGCS |  | 401d? | 2004-08-27 | 2006-03-10 |  |  | 2004-08-27 | 2005-12-06 | 333d? | 225d | finish no earlier than 2006-03-10 | C4 | 3208h |  | EVGCS | Siemens |  | Rel-7 |  |  |
| 123 | 30.3 | GERAN2 aspects |  | 436d? | 2004-08-27 A | 2006-04-28 | 60% | 174.4d? | 2004-08-27 | 2005-11-11 | 316d? | 190d | finish no earlier than 2006-04-28 | G2 | 3488h | 2092.8h | EVGCS | Ken Isaacs (Siemens) | kenneth.isaacs@roke.co.uk | Rel-7 | TSG | Gert |
| 124 | 31 | **Improvements of VGCS for parallel use of services** |  | 194d? | 2005-03-15 A | 2005-12-09 | 12% | 170.5d? | 2005-03-15 | 2005-12-09 | 194d? | 290d |  | S1 | 7334.16h | 612.4h | IVGCS |  |  | Rel-7 |  |  |
| 125 | 31.1 | Service Requirements for VGCS improvements |  | 62d? | 2005-03-15 A | 2005-06-08 A | 100% |  | 2005-03-15 | 2005-06-08 | 62d? |  | finish no earlier than 2005-06-08 | S1 | 496h | 496h | IVGCS | Kurt Bischinger (T-Mobile) | kurt.bischinger@t-mobile.at | Rel-7 | TSG | Michael |
| 126 | 31.2 | Stage 2 modifications for VGCS improvements |  | 142d? | 2005-03-15 | 2005-09-28 |  |  | 2005-03-15 | 2005-09-28 | 142d? | 342d | finish no earlier than 2005-09-28 | C1 | 1136h |  | IVGCS | Kurt Bischinger (T-Mobile) | kurt.bischinger@t-mobile.at | Rel-7 | TSG |  |
| 127 | 31.3 | **Architecture and protocol aspects** |  | 194d? | 2005-03-15 A | 2005-12-09 | 3% | 189.15d? | 2005-03-15 | 2005-12-09 | 194d? | 290d |  | C1 | 4656h | 116.4h | IVGCS | Dieter Jacobsohn (T-Mobile) |  | Rel-7 |  |  |
| 128 | 31.3.1 | CT1 aspects of IVGCS |  | 194d? | 2005-03-15 A | 2005-12-09 | 5% | 184.3d? | 2005-03-15 | 2005-12-09 | 194d? | 290d | finish no earlier than 2005-12-09 | C1 | 1552h | 77.6h | IVGCS | T-Mobile |  | Rel-7 |  |  |
| 129 | 31.3.2 | CT4 aspects of IVGCS |  | 194d? | 2005-03-15 | 2005-12-09 |  |  | 2005-03-15 | 2005-12-09 | 194d? | 290d | finish no earlier than 2005-12-09 | C4 | 1552h |  | IVGCS | T-mobile |  | Rel-7 |  |  |
| 130 | 32 | **OSA Rel-7** |  | 394d? | 2005-03-15 A | 2006-09-15 | 10% | 353.36d? | 2005-03-15 | 2005-09-28 | 142d? | 90d |  | S1 | 8752h | 902.71h | OSA7 | Eamonn Murray (AePONA) | eamonn.murray@aepona.com | Rel-7 | TSG | Michael |
| 131 | 32.1 | Service Requirements for OSA Service Broker |  | 62d? | 2005-03-15 A | 2005-06-08 | 65% | 21.7d? | 2005-03-15 | 2005-06-08 | 62d? | 422d | finish no earlier than 2005-06-08 | S1 | 496h | 322.4h | OSA7-SB | Eamonn Murray (AePONA) | eamonn.murray@aepona.com | Rel-7 | TSG | Michael |
| 132 | 32.2 | Stage 2 modifications for OSA Service Broker |  | 394d? | 2005-03-15 A | 2006-09-15 | 5% | 374.3d? | 2005-03-15 | 2005-09-28 | 142d? | 90d | finish no earlier than 2006-09-15 | C5 | 3152h | 157.6h | OSA7-SB | Eamonn Murray (AePONA) | eamonn.murray@aepona.com | Rel-7 | TSG | Adrian |
| 133 | 32.3 | New OSA Stage 2/3 enhancements |  | 244d? | 2005-10-11 A | 2006-09-15 | 5% | 231.8d? |  |  |  | 90d | finish no earlier than 2006-09-15 | C5 | 1952h | 97.6h | OSA7 | Damian O’Neill (AePONA) | damian.oneill@aepona.com | Rel-7 |  | Adrian |
| 134 | 33 | Dynamic and interactive multimedia scenes |  | 402d? | 2005-03-15 A | 2006-09-27 | 25% | 301.5d? | 2005-03-15 | 2006-09-27 | 402d? | 82d | finish no earlier than 2006-09-27 | S4 | 3216h | 804h | DIMS | Gaëlle MARTIN-COCHER (Streamezzo) | gaelle.martin-cocher@streamezzo.com | Rel-7 | TSG | Paolo |
| 135 | 34 | Liberty Alliance and 3GPP Security Interworking |  | 147d? | 2005-03-10 A | 2005-09-30 | 20% | 117.6d? | 2005-03-10 | 2005-09-30 | 147d? | 340d | finish no earlier than 2005-09-30 | S3 | 1176h | 235.2h | LibSec | Silke Holtmanns, Nokia | Silke.Holtmanns@NOKIA.COM | Rel-7 | TSG | Maurice |

Notes:
- 112: Not started
- 113: Started / Text3: 25.9xx, 45.005
- 114: Started / Text3: 24.008, 43.022, 44.018, 44.118, 45, 001, 45.005, 51.010, 51.021
- 115: Completed / Text3: 24.008, 43.022, 44.018, 44.118, 45, 001, 45.005,
- 116: Started / Text3: 51.010, 51.021
- 117: Started / Text3: 51.010, 51.021
- 118: Text3: 43.068, 44.068, 24.008, 29.002
- 119: Text3: 42.068, 43.068
- 120: Text3: 43.068, 44.068
- 121: Text3: 43.068, 44.068, 24.008
- 122: Text3: 29.002
- 125: "completeed" as from Chris S' e-mail / Text3: 42.068
- 126: Text3: 43.068
- 127: Text3: 44.068
- 128: Text3: 43.068, 44.068, 24.008
- 129: Text3: 29.002
- 131: az: WID URL corrected / Text3: 22.127
- 132: Completion => 09/2006 / Text3: 23.198
- 133: CT#30: WID approved. / Text3: 23.198, 29.198,29.998,29.199
- 134: Started / Text3: 26.234, 23.346, 26.140, 26.244
- 135: WID approved SA#27. / Text3: 33.980

| ID | WBS | Task | Type | Duration | Start | Finish | Complete | Remaining | Baseline start | Baseline finish | Baseline duration | Total slack | Constraint | Resources | Work | Actual work | Text4 | Text5 | Text6 | Text7 | Text8 | Text1 | Text10 |
| --- | --- | --- | --- | --- | --- | --- | --- | --- | --- | --- | --- | --- | --- | --- | --- | --- | --- | --- | --- | --- | --- | --- | --- |
| 136 | 35 | **WLAN-UMTS Interworking Phase 2** |  | 710d? | 2004-01-05 A | 2006-09-22 | 18% | 583.61d? | 2004-01-05 | 2005-06-07 | 371d? | 85d |  | S1 | 10848h | 3888h | Fredric Paint, Telenor | frederic.paint@telenor.com | Rel-7 | TSG | Michael |  |  |
| 137 | 35.1 | Stage 1 on Session Continuity |  | 115d? | 2004-01-05 A | 2004-06-11 A | 100% |  | 2004-01-05 | 2004-06-11 | 115d? |  | start no earlier than 2004-01-05 | S1 | 920h | 920h |  |  | Rel-7 |  |  | WLAN-SC | SP-24 |
| 138 | 35.2 | Stage 2 on Session Continuity: covered by SAE | milestone | 0d? | 2005-06-07 | 2005-06-07 |  |  | 2005-06-07 | 2005-06-07 | 0d? | 424d | finish no earlier than 2005-06-07 | S2 |  |  |  |  | Rel-7 |  |  |  |  |
| 139 | 35.3 | DIAMETER on the PDG Wi inteface |  | 531d? | 2004-09-10 | 2006-09-22 |  |  | 2004-09-10 | 2005-09-16 | 266d? | 85d | finish no earlier than 2006-09-22 | C3 | 4248h |  |  |  | Rel-7 | TSG | Seung Don | DIAMWi |  |
| 140 | 36 | **Voice call continuity between CS and IMS (incl. I-WLAN)** |  | 441d? | 2004-12-31 A | 2006-09-08 | 33% | 296.94d? | 2004-12-31 | 2006-06-23 | 386d? | 95d |  | S2 | 14992h | 4018.72h | Andy Bennett, Lucent; Roger Bunting, Cingular | andybennett@lucent.com | Rel-7 |  | Maurice | VCC |  |
| 141 | 36.1 | TR for VCC |  | 245d? | 2004-12-31 A | 2005-12-08 A | 100% |  | 2004-12-31 | 2005-12-08 | 245d? |  | finish no earlier than 2005-12-08 | S2 | 1960h | 1960h |  |  | Rel-7 |  |  | VCC |  |
| 142 | 36.2 | Stage 1 for VCC |  | 140d? | 2005-03-17 A | 2005-09-28 A | 100% |  | 2005-03-17 | 2005-09-28 | 140d? |  | finish no earlier than 2005-09-28 | S1 | 1120h | 1120h |  |  | Rel-7 |  | Mike | VCC |  |
| 143 | 36.3 | Stage 2 for VCC |  | 264d? | 2005-09-06 A | 2006-09-08 | 5% | 250.8d? | 2005-09-06 | 2006-06-09 | 199d? | 95d | finish no earlier than 2006-09-08 | S2 | 2112h | 105.6h |  |  | Rel-7 |  |  | VCC |  |
| 144 | 36.4 | **Stage 3 for VCC** |  | 196d? | 2005-09-23 A | 2006-06-23 | 1% | 194.04d? | 2005-09-23 | 2006-06-23 | 196d? | 150d |  | C1 | 6272h | 62.72h |  |  | Rel-7 |  |  | VCC |  |
| 145 | 36.4.1 | CT1 aspects of VCC |  | 196d? | 2005-09-23 A | 2006-06-23 | 3% | 190.12d? | 2005-09-23 | 2006-06-23 | 196d? | 150d | finish no earlier than 2006-06-23 | C1 | 1568h | 47.04h | Lucent |  | Rel-7 |  |  | VCC |  |
| 146 | 36.4.2 | CT3 aspects of VCC |  | 196d? | 2005-09-23 | 2006-06-23 |  |  | 2005-09-23 | 2006-06-23 | 196d? | 150d | finish no earlier than 2006-06-23 | C3 | 1568h |  | Lucent |  | Rel-7 |  |  | VCC |  |
| 147 | 36.4.3 | CT4 aspects of VCC |  | 196d? | 2005-09-23 | 2006-06-23 |  |  | 2005-09-23 | 2006-06-23 | 196d? | 150d | finish no earlier than 2006-06-23 | C4 | 1568h |  | Lucent |  | Rel-7 |  |  | VCC |  |
| 148 | 37 | **OAM&P** |  | 740d? | 2004-02-16 A | 2006-12-15 | 20% | 590.17d? | 2004-02-16 | 2007-03-30 | 815d? | 25d |  | S5 | 102049h | 21510.5h | Christian TOCHE | toche@nortel.com | Rel-7 | TSG | Adrian | OAM7 |  |
| 149 | 37.1 | **Network Infrastructure Management** |  | 336d? | 2005-09-02 A | 2006-12-15 | 17% | 278.23d? | 2005-09-02 | 2006-12-22 | 341d? | 25d |  | S5 | 54592h | 8924.16h | Christian TOCHE | toche@nortel.com | Rel-7 |  |  | OAM7-NIM |  |
| 150 | 37.1.1 | Enhance NRM to accommodate NGN (IMS as basis of the Next Generation Network) |  | 336d? | 2005-09-02 | 2006-12-15 |  |  | 2005-09-02 | 2006-12-22 | 341d? | 25d | finish no earlier than 2006-12-15 | S5 | 2688h |  | BT |  | Rel-7 |  |  | OAM7-NIM-NGN |  |
| 151 | 37.1.2 | IRP usage scenarios |  | 336d? | 2005-09-02 A | 2006-12-15 | 1% | 332.64d? | 2005-09-02 | 2005-12-07 | 69d? | 25d | finish no earlier than 2006-12-15 | S5 | 2688h | 26.88h | Lucent |  | Rel-7 |  |  | OAM7-NIM |  |
| 152 | 37.1.3 | Co-operative Element Management interface (CO-OP) |  | 336d? | 2005-09-02 A | 2006-12-15 | 65% | 117.6d? | 2005-09-02 | 2006-03-31 | 151d? | 25d | finish no earlier than 2006-12-15 | S5 | 2688h | 1747.2h | Motorola |  | Rel-7 |  |  | OAM7-NIM-COOP |  |
| 153 | 37.1.4 | Network Management (NM) Itf-N performance criteria |  | 336d? | 2005-09-02 A | 2006-12-15 | 10% | 302.4d? | 2005-09-02 | 2005-12-07 | 69d? | 25d | finish no earlier than 2006-12-15 | S5 | 2688h | 268.8h | China Mobile |  | Rel-7 |  |  | OAM7-NIM |  |
| 154 | 37.1.5 | Delta synchronization between IRP Manager and IRP Agent |  | 336d? | 2005-09-02 A | 2006-12-15 | 45% | 184.8d? | 2005-09-02 | 2005-12-07 | 69d? | 25d | finish no earlier than 2006-12-15 | S5 | 2688h | 1209.6h | Siemens |  | Rel-7 |  |  | OAM7-NIM |  |
| 155 | 37.1.6 | Subscription Management (SuM) IRP Solution Sets |  | 336d? | 2005-09-02 A | 2006-12-15 | 45% | 184.8d? | 2005-09-02 | 2006-03-31 | 151d? | 25d | finish no earlier than 2006-12-15 | S5 | 2688h | 1209.6h | T-Mobile |  | Rel-7 |  |  | OAM7-NIM-SuM |  |
| 156 | 37.1.7 | Integration Reference Point (IRP) Security Management |  | 336d? | 2005-09-02 A | 2006-12-15 | 15% | 285.6d? | 2005-09-02 | 2006-06-30 | 216d? | 25d | finish no earlier than 2006-12-15 | S5 | 2688h | 403.2h | Huawei |  | Rel-7 |  |  | OAM7-NIM |  |
| 157 | 37.1.8 | Integration Reference Point (IRP) Methodology |  | 336d? | 2005-09-02 A | 2006-12-15 | 10% | 302.4d? | 2005-09-02 | 2006-12-07 | 330d? | 25d | finish no earlier than 2006-12-15 | S5 | 2688h | 268.8h | Ericsson |  | Rel-7 |  |  | OAM7-NIM |  |
| 158 | 37.1.9 | Partial suspension of Itf-N during maintenance/testing |  | 336d? | 2005-09-02 A | 2006-12-15 | 20% | 268.8d? | 2005-09-02 | 2005-12-07 | 69d? | 25d | finish no earlier than 2006-12-15 | S5 | 2688h | 537.6h | Siemens |  | Rel-7 |  |  | OAM7-NIM |  |
| 159 | 37.1.10 | Advanced Alarming on Itf-N |  | 336d? | 2005-09-02 A | 2006-12-15 | 35% | 218.4d? | 2005-09-02 | 2006-06-30 | 216d? | 25d | finish no earlier than 2006-12-15 | S5 | 2688h | 940.8h | Siemens |  | Rel-7 |  |  | OAM7-NIM |  |
| 160 | 37.1.11 | Management of Legacy Equipment |  | 336d? | 2005-09-02 | 2006-12-15 |  |  | 2005-09-02 | 2005-12-07 | 69d? | 25d | finish no earlier than 2006-12-15 | S5 | 2688h |  | Siemens |  | Rel-7 |  |  | OAM7-NIM |  |
| 161 | 37.1.12 | Rules for Vendor Specific Extensions |  | 336d? | 2005-09-02 A | 2006-12-15 | 10% | 302.4d? | 2005-09-02 | 2006-03-31 | 151d? | 25d | finish no earlier than 2006-12-15 | S5 | 2688h | 268.8h | Siemens |  | Rel-7 |  |  | OAM7-NIM |  |
| 162 | 37.1.13 | CN CS Bearer Transport Network (BTN) relative NRM |  | 336d? | 2005-09-02 A | 2006-12-15 | 40% | 201.6d? | 2005-09-02 | 2005-12-07 | 69d? | 25d | finish no earlier than 2006-12-15 | S5 | 2688h | 1075.2h | China Mobile |  | Rel-7 |  |  | OAM7-NIM |  |
| 163 | 37.1.14 | Backward and Forward Compatibility of IRP systems |  | 336d? | 2005-09-02 A | 2006-12-15 | 5% | 319.2d? | 2005-09-02 | 2006-12-22 | 341d? | 25d | finish no earlier than 2006-12-15 | S5 | 2688h | 134.4h | Ericsson |  | Rel-7 |  |  | OAM7-NIM-BFC |  |
| 164 | 37.1.15 | Study of Element Operations Systems Function (EOSF) definition |  | 336d? | 2005-09-02 A | 2006-12-15 | 5% | 319.2d? | 2005-09-02 | 2006-12-22 | 341d? | 25d | finish no earlier than 2006-12-15 | S5 | 2688h | 134.4h | China Mobile |  | Rel-7 |  |  | OAM7-NIM- EOSF |  |
| 165 | 37.1.16 | Study of SOAP/HTTP IRP Solution Sets |  | 336d? | 2005-09-02 A | 2006-12-15 | 1% | 332.64d? | 2005-09-02 | 2006-09-22 | 276d? | 25d | finish no earlier than 2006-12-15 | S5 | 2688h | 26.88h | Nortel |  | Rel-7 |  |  | OAM7-NIM-SOAP |  |
| 166 | 37.1.17 | Study of Itf-N Implementation Conformance Statement (ICS) template |  | 336d? | 2005-09-02 A | 2006-12-15 | 10% | 302.4d? | 2005-09-02 | 2006-09-22 | 276d? | 25d | finish no earlier than 2006-12-15 | S5 | 2688h | 268.8h | China Mobile |  | Rel-7 |  |  | OAM7-NIM-ICS |  |
| 167 | 37.1.18 | Study of IRP Information Model |  | 336d? | 2005-09-02 A | 2006-12-15 | 15% | 285.6d? | 2005-09-02 | 2006-09-22 | 276d? | 25d | finish no earlier than 2006-12-15 | S5 | 2688h | 403.2h | Motorola |  | Rel-7 |  |  | OAM7-NIM-IM |  |
| 168 | 37.1.19 | NEW Repeater Network Ressource Model (NRM) definition |  | 220d? | 2006-02-13 | 2006-12-15 |  |  |  |  |  | 25d | start no earlier than 2006-02-13 | S5 | 1760h |  | China Mobile |  | Rel-7 |  |  | OAM7-NIM |  |
| 169 | 37.1.20 | NEW UTRAN radio channel power monitoring |  | 220d? | 2006-02-13 | 2006-12-15 |  |  |  |  |  | 25d | start no earlier than 2006-02-13 | S5 | 1760h |  | China Mobile |  | Rel-7 |  |  | OAM7-NIM |  |

Notes:
- 136: Created at TSG#27 by A. Sultan because of WLAN items belonging to Rel-7
- 139: 13/12/2005 08:00 / Text3: 29.161
- 140: WID approved SA#27. Revised at SA#28. / Text3: 22.101, 22.228, 23.228
- 141: Text3: 23.806
- 143: Text3: 23.206
- 144: Text3: new TS, 24.229, 23.008, 23.009, 23.078, 29.078, 29.163, 29.228, 29.229, 29.230, 29.278, 29.328, 29.329
- 145: Text3: new TS, 24.229
- 146: Text3: 29.163
- 147: Text3: 23.008, 23.009, 23.078, 29.078, 29.228, 29.229, 29.230, 29.278, 29.328, 29.329
- 148: Created at TSG#27 by A. Sultan due to the split of the OAM BB Trace Rel-6/Rel-7 / Text3: see WT WIDs
- 149: SA#28 (06/2005) created / Text3: see WT WIDs
- 150: SA#28 (06/2005) created / Text3: 32.632, 32.633, 32.634, 32.635
- 151: SA#28 (06/2005) created. 09/05 Changed title to Study / Text3: new TR 32.8xy
- 152: SA#28 (06/2005) created. 09/05 Changed title to Study / Text3: new TR 32.8xy, 32.101
- 153: SA#28 (06/2005) created. 09/05 Changed title to Study / Text3: new TS 32.yzx
- 154: SA#28 (06/2005) created. 09/05 Changed title to Study / Text3: new TR 32.8xy,new TSs 32.111-n,32.60n; For n = 1 to 5
- 155: SA#28 (06/2005) created / Text3: 32.101,32.175, new TSs 32.161,32.307,32.317,32.607,32.617,32.667
- 156: SA#28 (06/2005) created / Text3: New TSs 32.372,32.373,32.374; 32.111,32.30x,32.32x,32.33x,32.34x,32.35x,32.36x,32.41x,32.60x,32.61x,32.66x
- 157: SA#28 (06/2005) created / Text3: New TSs 32.15w,32.15x,32.15y,32.15z; 32.150,32.151,32.152
- 158: SA#28 (06/2005) created. 09/05 Changed title to Study / Text3: new TR 32.8xy, new TSs 32.30n,32.60n,32.61n; For n = 1 to 5
- 159: SA#28 (06/2005) created. 09/05 Changed title to Study / Text3: new TR 32.8xy ; New TSs 32.111-n,32.30n; For n = 1 to 5
- 160: SA#28 (06/2005) created. 09/05 Changed title to Study / Text3: new TS 32.xxx, New TSs 32.62n,32.63n,32.64n,32.65n,32.71n,32.74n,32.69n; For n = 1 to 5
- 161: SA#28 (06/2005) created / Text3: 32.62n; For n = 1 to 5
- 162: SA#28 (06/2005) created / Text3: New Tss TS 32.xx1,TS 32.xx2,TS 32.xx3,TS 32.xx4
- 163: SA#29 (09/2005) created / Text3: TR 32.805. new TS 32.15X
- 164: SA#29 (09/2005) created / Text3: new TR 32.8xy
- 165: SA#29 (09/2005) created / Text3: new TR 32.8xy
- 166: SA#29 (09/2005) created / Text3: new TR 32.8xy
- 167: SA#29 (09/2005) created / Text3: new TR 32.8xy
- 168: SA#30 (12/2005) created / Text3: 32.64n; For n = 1 to 5
- 169: SA#30 (12/2005) created / Text3: 32.403, 32.64n; For n = 1 to 5

| ID | WBS | Task | Duration | Start | Finish | Complete | Remaining | Baseline start | Baseline finish | Baseline duration | Total slack | Constraint | Resources | Work | Actual work | Text1 | Text4 | Text5 | Text6 | Text7 | Text8 |
| --- | --- | --- | --- | --- | --- | --- | --- | --- | --- | --- | --- | --- | --- | --- | --- | --- | --- | --- | --- | --- | --- |
| 170 | 37.2 | **Performance Management** | 336d? | 2005-09-02 A | 2006-12-15 | 28% | 242.09d? | 2005-09-02 | 2006-12-29 | 346d? | 25d |  | S5 | 20576h | 4999.68h | OAM7-PM | Christian TOCHE | toche@nortel.com | Rel-7 |  |  |
| 171 | 37.2.1 | Performance measurements definition for CN CS | 336d? | 2005-09-02 A | 2006-12-15 | 60% | 134.4d? | 2005-09-02 | 2006-03-31 | 151d? | 25d | finish no earlier than 2006-12-15 | S5 | 2688h | 1612.8h | OAM7-PM | China Mobile |  | Rel-7 |  |  |
| 172 | 37.2.2 | Enhancement UTRAN performance measurements definition | 336d? | 2005-09-02 A | 2006-12-15 | 15% | 285.6d? | 2005-09-02 | 2005-12-07 | 69d? | 25d | finish no earlier than 2006-12-15 | S5 | 2688h | 403.2h | OAM7-PM | China Mobile |  | Rel-7 |  |  |
| 173 | 37.2.3 | Add TDD specific counters in Performance measurement | 336d? | 2005-09-02 A | 2006-12-15 | 75% | 84d? | 2005-09-02 | 2006-12-29 | 346d? | 25d | finish no earlier than 2006-12-15 | S5 | 2688h | 2016h | OAM7-PM | CATT |  | Rel-7 |  |  |
| 174 | 37.2.4 | ATM bearer network Performance measurements | 336d? | 2005-09-02 A | 2006-12-15 | 20% | 268.8d? | 2005-09-02 | 2005-12-07 | 69d? | 25d | finish no earlier than 2006-12-15 | S5 | 2688h | 537.6h | OAM7-PM | ZTE |  | Rel-7 |  |  |
| 175 | 37.2.5 | IP bearer network Performance measurement definitions | 336d? | 2005-09-02 A | 2006-12-15 | 15% | 285.6d? | 2005-09-02 | 2005-12-07 | 69d? | 25d | finish no earlier than 2006-12-15 | S5 | 2688h | 403.2h | OAM7-PM | China Mobile |  | Rel-7 |  |  |
| 176 | 37.2.6 | Performance measurements definition for IMS | 336d? | 2005-09-02 A | 2006-12-15 | 1% | 332.64d? | 2005-09-02 | 2006-12-22 | 341d? | 25d | finish no earlier than 2006-12-15 | S5 | 2688h | 26.88h | OAM7-PM-IMS | China Mobile |  | Rel-7 |  |  |
| 177 | 37.2.7 | NEW HSDPA performance measurements | 220d? | 2006-02-13 | 2006-12-15 |  |  |  |  |  | 25d | start no earlier than 2006-02-13 | S5 | 1760h |  | OAM7-PM | China Mobile |  | Rel-7 |  |  |
| 178 | 44.5 | **Trace Management** | 740d? | 2004-02-16 A | 2006-12-15 | 21% | 580.91d? | 2004-02-16 | 2007-03-30 | 815d? | 25d |  | S5 | 20961.1h | 3794.64h | OAM7-Trace | Christian TOCHE | toche@nortel.com | Rel-7 | TSG |  |
| 179 | 37.3.1 | Trace Management for IMS | 420d? | 2005-05-09 | 2006-12-15 |  |  | 2005-05-09 | 2005-12-08 | 154d? | 25d | finish no earlier than 2006-12-15 | S5 | 3360h |  | OAM7-Trace-IMS | Nortel |  | Rel-7 | TSG |  |
| 180 | 37.3.2 | SIP enhancements for trace | 603.14d? | 2004-02-16 A | 2006-06-16 | 2% | 591.08d? | 2004-02-16 | 2006-06-16 | 603.14d? | 155d | finish no earlier than 2006-06-16 | C1 | 4825.12h | 96.5h | OAM7-Trace-SIP |  |  | Rel-7 |  |  |
| 181 | 37.3.3 | End-to-end Service Level tracing for IMS | 286d? | 2005-11-11 A | 2006-12-15 | 35% | 185.9d? | 2005-11-11 | 2006-06-30 | 166d? | 25d | finish no earlier than 2006-12-15 | S5 | 2288h | 800.8h | OAM7-Trace-IMS | Vodafone |  | Rel-7 | TSG |  |
| 182 | 37.3.4 | IRP for Subscriber and Equipment Trace Management | 336d? | 2005-09-02 A | 2006-12-15 | 5% | 319.2d? | 2005-09-02 | 2007-03-30 | 411d? | 25d | finish no earlier than 2006-12-15 | S5 | 2688h | 134.4h | OAM7-Trace-IRP | Nortel |  | Rel-7 | TSG |  |
| 183 | 37.3.5 | Trace record content for UTRAN TDD | 420d? | 2005-05-09 A | 2006-12-15 | 75% | 105d? | 2005-05-09 | 2005-12-08 | 154d? | 25d | finish no earlier than 2006-12-15 | S5 | 3360h | 2520h | OAM7-Trace-TDD | CATT |  | Rel-7 | TSG |  |
| 184 | 38 | Trust Requirements for Open Platforms in 3GPP | 115d? | 2005-01-03 A | 2005-06-10 | 10% | 103.5d? | 2005-01-03 | 2005-06-10 | 115d? | 420d | finish no earlier than 2005-06-10 | S3 | 920h | 92h | TrustOP | Selim Aissi, Sundeep Bajikar, Intel Corporation |  | Rel-7 | TSG | Michael |
| 185 | 39 | Development of UEA2 and UIA2 | 268d? | 2004-12-01 A | 2005-12-09 | 65% | 93.8d? | 2004-12-01 | 2005-12-09 | 268d? | 290d | finish no earlier than 2005-12-09 | S3 | 2144h | 1393.6h | AlgUEA2 | Per Christoffersson, Teliasonera | per.christoffersson@teliasonera.com | Rel-7 | TSG | Michael |
| 186 | 40 | Lawful Interception in the 3GPP Rel-7 architecture | 118d? | 2005-06-28 A | 2005-12-08 | 40% | 70.8d? | 2005-06-28 | 2005-12-08 | 118d? | 291d | start no earlier than 2005-06-28 | S3 | 944h | 377.6h | LI-7A | Berthold Wilhelm, BMWI | berthold.wilhelm@regtp.de | Rel-7 |  | Mike |
| 187 | 41 | **Support of Conversational Services in A/Gb mode via the PS domain** | 276d? | 2005-04-08 A | 2006-04-28 |  | 276d? | 2005-04-08 | 2006-04-28 | 276d? | 190d |  | GP | 8611.2h | 198.72h | SCSAGB | Gunnar Hedby, Ericsson | gunnar.hedby@ericsson.com | Rel-7 |  | Paolo |
| 188 | 41.1 | Definition of radio resource management functionality | 276d? | 2005-04-08 | 2006-04-28 |  |  | 2005-04-08 | 2006-04-28 | 276d? | 190d | finish no earlier than 2006-04-28 | G1 | 2208h |  | SCSAGB-RRM | Gunnar Hedby, Ericsson | gunnar.hedby@ericsson.com | Rel-7 |  | Paolo |
| 189 | 41.2 | Radio Channel Support | 276d? | 2005-04-08 | 2006-04-28 |  |  | 2005-04-08 | 2006-04-28 | 276d? | 190d | finish no earlier than 2006-04-28 | G2 | 2208h |  | SCSAGB-RCHS | Gunnar Hedby, Ericsson | gunnar.hedby@ericsson.com | Rel-7 |  | Gert |
| 190 | 41.3 | Modifications to FLO | 276d? | 2005-04-08 | 2006-04-28 |  |  | 2005-04-08 | 2006-04-28 | 276d? | 190d | finish no earlier than 2006-04-28 | G2 | 2208h |  | SCSAGB-FLO | Gunnar Hedby, Ericsson | gunnar.hedby@ericsson.com | Rel-7 |  | Gert |
| 191 | 42 | **Addition of new frequency band to GSM (T-GSM810)** | 206d? | 2005-04-08 A | 2006-01-20 | 56% | 90.68d? | 2005-04-08 | 2005-11-18 | 161d? | 260d |  | GP | 5392h | 2096h | TGSM810 | Chen De, Huawei | chende@huawei.com | Rel-7 |  | Paolo |
| 192 | 42.1 | Changes to core specification | 106d? | 2005-04-08 A | 2005-09-02 A | 100% |  | 2005-04-08 | 2005-09-02 | 106d? |  | finish no earlier than 2005-09-02 | GP | 848h | 848h | TGSM810-Core | Chen De, Huawei | chende@huawei.com | Rel-7 |  | Paolo |
| 193 | 42.2 | Changes to MS testing specification | 206d? | 2005-04-08 | 2006-01-20 |  |  | 2005-04-08 | 2005-11-18 | 161d? | 260d | finish no earlier than 2006-01-20 | G3 | 1648h |  | TGSM810-Mstest | Chen De, Huawei | chende@huawei.com | Rel-7 |  | Stoyan |
| 194 | 42.3 | Changes to BTS testing specification | 156d? | 2005-04-08 A | 2005-11-11 A | 100% |  | 2005-04-08 | 2005-09-02 | 106d? |  | finish no earlier than 2005-11-11 | G1 | 1248h | 1248h | TGSM810-BTStest | Chen De, Huawei | chende@huawei.com | Rel-7 |  | Paolo |

Notes:
- 170: SA#28 (06/2005) created / Text3: see WT WIDs
- 171: Text3: New TS 32.xyz
- 172: Text3: 32.403
- 173: SA#28 (06/2005) created / Text3: 32.403
- 174: SA#28 (06/2005) created / Text3: 32.403
- 175: SA#28 (06/2005) created / Text3: 32.403
- 176: SA#29 (09/2005) created / Text3: new TS 32.xyz
- 177: SA#30 (12/2005) created / Text3: 32.403
- 178: TSG#27: SA5 BB WID to add Trace for IMS (SIP) CN1 24.229 has IETF dependency / Text3: see WT WIDs
- 179: Text3: 32.421,32.422,32.423
- 181: 07/2005: OMA (Stage 1), Stage 2/3 SA5, CT1/3/4 / Text3: 32.101,32.421,32.422,32.423
- 182: SA#29 (09/2005) created / Text3: 32.421,32.422,32.423. 3 new TS 32.4x1,2,3
- 183: Text3: 32.421,32.422,32.423
- 184: WID approved SA#26. Record created after SA#27
- 185: WID approved SA#26, Dependant on Funding Availability. Record created after SA#27 / Text3: 33.102
- 187: Originally started Nov. 2003 as GP-030443
- 191: Text3: 45.005, 45.050, 24.008, 45.008, 45.001, 43.022, 43.030, 44.018, 44.060, 51.010-1, 51.021
- 192: Text3: 45.005, 45.050, 24.008, 45.008, 45.001, 43.022, 43.030, 44.018, 44.060
- 193: Not started / Text3: 51010-1
- 194: Text3: 51021

| ID | WBS | Task | Type | Duration | Start | Finish | Complete | Remaining | Baseline start | Baseline finish | Baseline duration | Total slack | Constraint | Resources | Work | Actual work | Text1 | Text4 | Text5 | Text6 | Text8 | Text3 | Text12 | Text7 |
| --- | --- | --- | --- | --- | --- | --- | --- | --- | --- | --- | --- | --- | --- | --- | --- | --- | --- | --- | --- | --- | --- | --- | --- | --- |
| 195 | 43 | **Handover of dedicated and shared resources while in dual transfer mode** |  | 276d? | 2005-04-08 A | 2006-04-28 | 10% | 248.4d? | 2005-04-08 | 2006-11-17 | 421d? | 190d |  | GP | 8832h | 662.4h | HODSRDTM | Rami Vaittinen, Nokia | rami.vaittinen@nokia.com | Rel-7 | Paolo |  |  |  |
| 196 | 43.1 | Handover of dedicated and shared resources while in dual transfer mode |  | 276d? | 2005-04-08 A | 2006-04-28 | 30% | 193.2d? | 2005-04-08 | 2006-04-28 | 276d? | 190d | finish no earlier than 2006-04-28 | G2 | 2208h | 662.4h | HODSRDTM-G2 | Rami Vaittinen, Nokia | rami.vaittinen@nokia.com | Rel-7 | Gert | 43.055, 44.018, 44.060 |  |  |
| 197 | 43.2 | MS Conformance Testing |  | 276d? | 2005-04-08 | 2006-04-28 |  |  |  |  |  | 190d | start no earlier than 2005-04-08 | G3 | 2208h |  | HODSRDTM-Mstest | Rami Vaittinen, Nokia | rami.vaittinen@nokia.com | Rel-7 | Stoyan | 51-010 |  |  |
| 198 | 43.3 | BTS conformance testing |  | 276d? | 2005-04-08 | 2006-04-28 |  |  | 2005-04-08 | 2006-11-17 | 421d? | 190d | finish no earlier than 2006-04-28 | G1 | 2208h |  | HODSRDTM-BTStest | Rami Vaittinen, Nokia | rami.vaittinen@nokia.com | Rel-7 | Paolo | 51.026 |  |  |
| 199 | 44 | Future GERAN Evolution |  | 206d? | 2005-04-08 A | 2006-01-20 | 75% | 51.5d? | 2005-04-08 | 2005-11-11 | 156d? | 260d | finish no earlier than 2006-01-20 | GP | 1648h | 1236h | FGE | Eddie Riddington, Nokia Corporation | eddie.riddington@nokia.com | Rel-7 | Paolo |  |  |  |
| 200 | 45 | 3G-324M Video Telephony Call Setup Times Improvements |  | 341d? | 2005-06-08 A | 2006-09-27 | 50% | 170.5d? | 2005-06-08 | 2006-09-27 | 341d? | 82d | finish no earlier than 2006-09-27 | S4 | 2728h | 1364h | VTCSTI | Edward Hall (Vodafone) | edward.hall@vodafone.co.uk | Rel-7 | Paolo | 26.abc |  |  |
| 201 | 46 | DELETED- Covered by SI - Personal Network (PN) and Personal Area Network (PAN) |  | 101.2d? | 2005-07-11 A | 2005-12-08 | 70% | 30.36d? | 2005-07-11 | 2005-12-08 | 101.2d? | 291d | finish no earlier than 2005-12-08 | S1 | 809.6h | 566.72h | PNPAN | Armin Toepfer, Vodafone | armin.toepfer@vodafone.com | Rel-7 | Mike |  | SP-30 |  |
| 202 | 47 | DELETED- Covered by SI - Multimedia Telephony Capabilities for IMS |  | 101.2d? | 2005-07-11 A | 2005-12-08 | 70% | 30.36d? | 2005-07-11 | 2005-12-08 | 101.2d? | 291d | finish no earlier than 2005-12-08 | S1 | 809.6h | 566.72h | MITE | Peter Bleckert, Ericsson | peter.bleckert @ericsson.com | Rel-7 | Mike |  | SP-30 |  |
| 203 | 48 | DELETED- Covered by SI - Transferring of emergency Call data |  | 109d? | 2005-07-11 A | 2005-12-08 | 70% | 32.7d? | 2005-07-11 | 2005-12-08 | 109d? | 291d | finish no earlier than 2005-12-08 | S1 | 872h | 610.4h | eCALL | Steve Vardy, (Motorola S.A.S) | steven.vardy@motorola.com | Rel-7 | Mike |  | SP-30 |  |
| 204 | 49 | DELETED- Covered by SI - MBMS Enhancements |  | 109d? | 2005-07-11 A | 2005-12-08 | 20% | 87.2d? | 2005-07-11 | 2005-12-08 | 109d? | 291d | finish no earlier than 2005-12-08 | S1 | 872h | 174.4h | MBMSE | Liu Hong, China Mobile | liuhongyfw@chinamobile.com | Rel-7 | Mike |  | SP-30 |  |
| 205 | 50 | **Identification of Communication Services in IMS** |  | 355d? | 2005-05-02 A | 2006-09-08 | 33% | 236.14d? | 2005-05-02 | 2006-09-08 | 355d? | 95d |  | S2 | 6424h | 1328h | ServID | Stephen Terrill, Ericsson | stephen.terrill@ericsson.com | Rel-7 | Maurice | 23.228, 23.218, 23.125 |  |  |
| 206 | 50.1 | TR for ICS |  | 232d? | 2005-05-02 A | 2006-03-21 | 60% | 92.8d? | 2005-05-02 | 2006-03-21 | 232d? | 218d | finish no earlier than 2006-03-20 | S2 | 1856h | 1113.6h | ServID |  |  | Rel-7 |  | 23.816 |  |  |
| 207 | 50.2 | Stage 2 for ICS |  | 216d? | 2005-11-11 A | 2006-09-08 | 5% | 205.2d? | 2006-03-27 | 2006-09-08 | 120d? | 95d | start no earlier than 2005-11-11 | S2 | 1728h | 86.4h | ServID |  |  | Rel-7 |  |  |  |  |
| 208 | 51 | **VoIMS bearer related enhancements** |  | 402d? | 2005-03-15 A | 2006-09-27 | 38% | 249.25d? | 2005-03-15 | 2006-07-21 | 354d? | 82d |  | S2 | 10463.2h | 2793.6h | VoIMS |  |  | Rel-7 |  |  |  |  |
| 209 | 51.1 | FS on enhancement of radio performance for VoIMS |  | 320d? | 2005-05-02 A | 2006-07-21 | 35% | 208d? | 2005-05-02 | 2006-07-21 | 320d? | 130d | finish no earlier than 2006-07-21 | S2 | 2560h | 896h | VoIMS | Laurence Lautier, Nortel Networks | lautierl@nortel.com | Rel-7 | Maurice | 23.807 |  |  |
| 210 | 51.2 | Improved support of IMS Realtime Services using HSDPA/HSUPA |  | 197d? | 2005-03-15 A | 2005-12-14 A | 100% |  | 2005-03-15 | 2005-12-14 | 197d? |  | start no earlier than 2005-03-15 | R2 | 1576h | 1576h | RANimp-IMSRealTime | Don Zelmer | don.zelmer@CINGULAR.COM | Rel-7 | MCC_RAN |  |  | TSG |
| 211 | 51.3 | Performance Characterization of VoIMS over HSDPA\EUL channels |  | 402d? | 2005-03-15 A | 2006-09-27 | 10% | 361.8d? | 2005-03-15 | 2006-03-15 | 262d? | 82d | finish no earlier than 2006-09-27 | S4 | 3216h | 321.6h | VoIMS-PCVoIMS | Dimitris Vasilaras (Lucent Technologies) | dvasilaras@lucent.com | Rel-7 | Paolo | 26.935 |  | TSG |
| 212 | 52 | **Optimizations for Multimedia Telephony over IMS** |  | 261d? | 2005-09-28 A | 2006-09-27 | 5% | 247.95d? | 2005-09-28 | 2006-09-27 | 261d? | 82d |  | S4 | 4176h | 208.8h | OMTIMS | Olle Franceschi (Ericsson) | olle.franceschi@ericsson.com | Rel-7 | Paolo | 26.235, 26.236 |  |  |
| 213 | 52.1 | Characterisation of Adaptive Jitter Management Performance for VoIP Services |  | 261d? | 2005-09-28 A | 2006-09-27 | 5% | 247.95d? | 2005-09-28 | 2006-09-27 | 261d? | 82d | finish no earlier than 2006-09-27 | S4 | 2088h | 104.4h | OMTIMS-CAJMP | David Huo (Lucent Technologies) | dhuo@lucent.com | Rel-7 | Paolo |  |  |  |
| 214 | 53 | End-to-End Multimedia Services Performance Metrics |  | 261d? | 2005-09-28 | 2006-09-27 |  |  | 2005-09-28 | 2006-09-27 | 261d? | 82d | finish no earlier than 2006-09-27 | S4 | 2088h |  | E2EMSPM | Zhang Yan (China Mobile) | zhangyanyf@chinamobile.com | Rel-7 | Paolo |  |  |  |
| 215 | 54 | **WLAN Interworking – Private Network access from WLAN 3GPP IP Access** |  | 185d? | 2005-10-10 A | 2006-06-23 | 5% | 175.15d? | 2005-10-10 | 2006-10-20 | 270d? | 150d |  | S2 | 6920h | 296h | WLANPNA |  |  | Rel-7 | Maurice |  |  |  |
| 216 | 54.1 | WLAN-PNA - Stage 2 |  | 185d? | 2005-10-10 A | 2006-06-23 | 20% | 148d? |  |  |  | 150d | start no earlier than 2005-10-10 | S2 | 1480h | 296h | WLANPNA-st2 | Toshiyuki Tamura (NEC) | tamurato@aj.jp.nec.com | Rel-7 | Maurice | 23.234, 33.234 |  |  |
| 217 | 54.2 | **WLAN-PNA - Stage 3** |  | 170d? | 2005-10-10 | 2006-06-02 |  |  | 2005-10-10 | 2006-10-20 | 206.31d? | 165d |  | C1 | 5440h |  | WLANPNA-St3 | Pierre-Jean Muller (NEC) | pierre-jean.muller@nectech.fr | Rel-7 | Andrijana |  |  | TSG |
| 218 | 54.2.1 | CT1 aspets for WLAN-PNA |  | 170d? | 2005-10-10 | 2006-06-02 |  |  |  |  |  | 165d | finish no earlier than 2006-06-02 | C1 | 1360h |  | WLANPNA-st3-CT1 | Pierre-Jean Muller (NEC) | pierre-jean.muller@nectech.fr | Rel-7 | Andrijana | 24.234 |  |  |
| 219 | 54.2.2 | CT3 aspets for WLAN-PNA |  | 170d? | 2005-10-10 | 2006-06-02 |  |  |  |  |  | 165d | finish no earlier than 2006-06-02 | C3 | 1360h |  | WLANPNA-st3-CT3 | Pierre-Jean Muller (NEC) | pierre-jean.muller@nectech.fr | Rel-7 | Andrijana | 29.161 |  |  |
| 220 | 54.2.3 | CT4 aspets for WLAN-PNA |  | 170d? | 2005-10-10 | 2006-06-02 |  |  |  |  |  | 165d | finish no earlier than 2006-06-02 | C4 | 1360h |  | WLANPNA-st3-CT4 | Pierre-Jean Muller (NEC) | pierre-jean.muller@nectech.fr | Rel-7 | Andrijana | 29.234 |  |  |
| 221 | 55 | Supporting Globally Routable User Agent URIs in IMS | milestone | 0d? | 2005-10-10 A | 2006-10-20 |  | 0d? | 2005-10-10 | 2006-10-20 | 0d? | 0d | finish no earlier than 2006-06-23 | S2 |  |  | GRUU | Adrian Buckley (Research In Motion) | abuckley@rim.com | Rel-7 | Maurice | 23.8XX, 22.228, 23.228, 23.218, 24.229 |  |  |
| 222 | 56 | ISIM API for Java Card |  | 200d? | 2005-03-14 A | 2005-12-16 | 90% | 20d? |  |  |  | 285d | finish no earlier than 2005-12-16 | C6 | 1600h | 1440h | APIJAVA | Sebastian Hans, Sun Microsystems Ltd. |  | Rel-7 | Gaby | 31.103, TS 102 241 |  |  |

Notes:
- 195: Started at GERAN#24
- 196: Started at GERAN#24
- 197: Not started
- 198: Not started
- 199: FS started
- 200: Conditionally, in the event Phase 2 is needed, end is Dec.06
- 205: WID approved SA#28
- 208: Created by MCC to group all VoIMS related items, after consultation of chairs
- 209: WID approved SA#28
- 211: Started
- 215: Placeholder created to Hold SA2 and CT1 BBs
- 216: Approved at SP#29
- 217: Approved at CP#29
- 218: Approved at CP#29
- 219: Approved at CP#29
- 220: Approved at CP#29
- 221: Approved at SP#29

| ID | WBS | Task | Type | Duration | Start | Finish | Complete | Remaining | Baseline start | Baseline finish | Baseline duration | Total slack | Constraint | Resources | Work | Actual work | Text1 | Text6 | Text3 | Text4 | Text5 | Text8 | Text7 |
| --- | --- | --- | --- | --- | --- | --- | --- | --- | --- | --- | --- | --- | --- | --- | --- | --- | --- | --- | --- | --- | --- | --- | --- |
| 223 | 57 | **Rel7 Security enhancements** |  | 130d? | 2005-09-12 A | 2006-03-10 | 70% | 38.9d? |  |  |  | 225d |  | S3 | 2584h | 1810.81h | SEC7 | Rel-7 |  |  |  |  |  |
| 224 | 57.1 | HTTPS connection between a UICC and a NAF |  | 1d? | 2005-09-12 A | 2005-09-12 | 90% | 0.1d? |  |  |  | 354d | start no earlier than 2005-09-12 | S3 | 8h | 7.2h | SEC7-HSUN | Rel-7 | 33.222, 24.109, 33.918 | Jacques Seif (Axlato) | JSeif@axalto.com |  |  |
| 225 | 57.2 | 2G GBA: 2G SIM usage in 3GPP GAA framework |  | 61d? | 2005-09-12 A | 2005-12-05 | 60% | 24.4d? |  |  |  | 294d | finish no earlier than 2005-12-05 | S3 | 488h | 292.8h | SEC7-2GGBA | Rel-7 | 33.220, 33.290 | Silke Holtmanns (Nokia) | Silke.Holtmanns@nokia.com |  |  |
| 226 | 57.3 | Generic Authentication Architecture usage extensions and optimisations |  | 1d? | 2005-09-12 A | 2005-09-12 | 25% | 0.75d? |  |  |  | 354d | start no earlier than 2005-09-12 | S3 | 8h | 2h | SEC7-GAA2 | Rel-7 | 33.220, 29.109 | Silke Holtmanns (Nokia) | Silke.Holtmanns@nokia.com |  |  |
| 227 | 57.4 | Network Domain Security; SS7 security Gateway (NDS/TCAPsec) |  | 130d? | 2005-09-12 A | 2006-03-10 | 75% | 32.5d? |  |  |  | 225d | finish no earlier than 2006-03-10 | S3 | 1040h | 780h | SEC7-NDS-TCAPsec | Rel-7 | 33.200, 33.204 | Marc Blommaert (Siemens) | marc.blommaert@siemens.com |  |  |
| 228 | 58 | IMS Service Brokering enhancements |  | 69d? | 2005-12-07 A | 2006-03-13 | 50% | 34.5d? | 2005-11-04 | 2006-06-16 | 161d? | 224d | finish no earlier than 2006-03-13 | S1 | 552h | 276h | ISB | Rel-7 | 22.228 | John-Luc Bakker (Telcordia) | jbakker@telcordia.com | Michael |  |
| 229 | 59 | Network Composition |  | 211d? | 2005-12-07 A | 2006-09-27 | 5% | 200.45d? |  |  |  | 82d | finish no earlier than 2006-09-27 | S1 | 1688h | 84.4h | NetComp | Rel-7 | 22.xxx | Joerg Swetina (Siemens) | joerg.swetina@siemens.com |  |  |
| 230 | 60 | Key establishment between a UICC and a terminal |  | 201.45d? | 2005-12-07 A | 2006-09-28 | 5% | 191.38d? |  |  |  | 81d | finish no earlier than 2006-09-28 | S3 | 1611.6h | 80.58h | KeyEstUTerm | Rel-7 | 33.xxx | Mireille Pauliac (Gemplus) | mireille.pauliac@gemplus.com |  |  |
| 231 | 61 | **Mobile Station Receive Diversity (DARP Phase II)** |  | 311d? | 2005-11-11 | 2007-01-19 |  |  |  |  |  | 0d |  | GP | 9400h |  | MSRD2 | Rel-7 | 24.008, 45.005, 51.010 | Kent Pedersen, Nokia Corporation (ETSI) | kent.pedersen@nokia.com | Paolo |  |
| 232 | 61.1 | MS conformance test of DARP Phase II (MSRD) |  | 311d? | 2005-11-11 | 2007-01-19 |  |  |  |  |  | 0d | finish no earlier than 2007-01-19 | GP | 2488h |  | MSRD2-Msconf | Rel-7 | 51.010 | Kent Pedersen, Nokia Corporation (ETSI) | kent.pedersen@nokia.com | Paolo, Stoyan |  |
| 233 | 61.2 | Performance Requirements for Mobile Station Receive Diversity, DARP Phase II |  | 216d? | 2005-11-11 | 2006-09-08 |  |  |  |  |  | 95d | finish no earlier than 2006-09-08 | GP | 1728h |  | MSRD2-PerfReq | Rel-7 | 45.005 | Kent Pedersen, Nokia Corporation (ETSI) | kent.pedersen@nokia.com | Paolo |  |
| 234 | 61.3 | Capability signalling of Mobile Station Receive Diversity, DARP Phase II |  | 216d? | 2005-11-11 | 2006-09-08 |  |  |  |  |  | 95d | finish no earlier than 2006-09-08 | GP | 1728h |  | MSRD2-CapSig | Rel-7 | 24.008 | Kent Pedersen, Nokia Corporation (ETSI) | kent.pedersen@nokia.com | Paolo, Gert |  |
| 235 | 61.4 | Test Scenarios for Mobile Station Receive Diversity, DARP Phase II |  | 121d? | 2005-11-11 | 2006-04-28 |  |  |  |  |  | 190d | finish no earlier than 2006-04-28 | GP | 968h |  | MSRD2-TestSc | Rel-7 | 45.005 | Kent Pedersen, Nokia Corporation (ETSI) | kent.pedersen@nokia.com | Paolo |  |
| 236 | 62 | MBMS User Service Extensions |  | 261d? | 2005-12-07 | 2006-12-06 |  |  |  |  |  | 32d | finish no earlier than 2006-12-06 | S4 | 2088h |  | MBMSUSE | Rel-7 | 26.346, 26.946 | Thorsten Lohmar (Ericsson) | Thorsten.Lohmar@ericsson.com | Paolo |  |
| 237 | 63 | IMS Support of Conferencing and Messaging Group Management |  | 90d? | 2005-11-04 A | 2006-03-09 | 10% | 81d? |  |  |  | 226d | start no earlier than 2005-11-04 | C1 | 720h | 72h | IMSconf | Rel-7 |  | Keith Drage (Lucent) |  | Andrijana |  |
| 238 | 64 | (Small) Technical Enhancements and Improvements for Rel-7 |  | 400d? | 2005-06-06 | 2006-12-15 |  |  |  |  |  | 25d | finish no earlier than 2006-12-15 | All | 3200h |  | TEI7 | Rel-7 |  |  |  |  |  |
| 239 | 65 | Rel-7 Feasibility Studies listed below |  | 1d? | 2000-01-03 | 2000-01-03 |  |  | 2000-01-03 | 2000-01-03 | 1d? | 1839d |  |  |  |  |  | Rel-7 |  |  |  |  |  |
| 240 | 66 | Study Item on IMS enhancements and optimisations for real time communication. | milestone | 0d? | 2005-10-10 A | 2006-10-20 | 10% | 0d? | 2005-10-10 | 2006-10-20 | 0d? | 0d | finish no earlier than 2006-09-22 | S2 |  |  | IMS-RT | Rel-7 | 23.8yz | Stephen Terrill (Ericsson) | stephen.terrill@ericsson.com | Maurice |  |
| 241 | 67 | Behaviour of Multi system UEs |  | 188d? | 2004-06-28 A | 2005-03-16 | 95% | 9.4d? | 2004-06-28 | 2005-03-16 | 188d? | 482d | start no earlier than 2004-06-28 | S1 | 1504h | 1428.8h | BMSU | Rel-7 | 22.936 | D Williams (QUALCOMM) | dwilliams@qualcomm.com | Michael | TSG |
| 242 | 68 | **FS on IMS with real time services deployment** |  | 384d? | 2004-06-28 A | 2005-12-15 | 99% | 0d? | 2004-06-28 | 2005-12-15 | 384d? | 0d |  | S1 | 8672h | 6304.24h | IRTSD | Rel-7 |  |  |  | Maurice | TSG |
| 243 | 68.1 | Feasibility Study on Combining CS calls and IMS sessions |  | 384d? | 2004-06-28 A | 2005-12-15 A | 100% |  | 2004-06-28 | 2005-12-15 | 384d? |  | start no earlier than 2004-06-28 | S1 | 3072h | 3072h | IRTSD-CS_IMS | Rel-7 | 22.979, 23.899 |  |  | Michael | TSG |
| 244 | 68.2 | TR on Stage 2 (IMS services using CS bearers) |  | 316d? | 2004-06-28 A | 2005-09-12 A | 100% |  | 2004-06-28 | 2005-09-12 | 316d? |  | finish no earlier than 2005-09-12 | S2 | 2528h | 2528h | IRTSD-IMSCS | Rel-7 | 23.899 | Mark Watson (Nortel Networks) |  | Maurice | TSG |
| 245 | 69 | TR on interworking related aspects |  | 251d? | 2004-06-28 A | 2005-06-13 | 50% | 125.5d? |  |  |  | 419d |  | S2 | 2008h | 1004h | IRTSD-IMSCS | Rel-7 |  | Osok Song (Samsung) |  | Maurice |  |
| 246 | 70 | **3GPP System Architecture Evolution** |  | 466d? | 2004-12-03 A | 2006-09-15 | 50% | 234.16d? | 2004-12-03 | 2006-06-16 | 401d? | 90d |  | S2 | 9144h | 4549.31h | SAE | Rel-7 |  |  |  |  | TSG |
| 247 | 70.1 | Stage 2 Interim conclusion for RAN Work to start |  | 211d? | 2004-12-03 A | 2005-09-23 A | 100% |  | 2004-12-03 | 2005-09-23 | 211d? |  | finish no earlier than 2005-09-23 | S2 | 1688h | 1688h | SAE | Rel-7 | 23.882 |  |  |  |  |
| 248 | 70.2 | Stage 2 Feasibility study on 3GPP architectural development |  | 466d? | 2004-12-03 A | 2006-09-15 | 27% | 340.18d? | 2004-12-03 | 2006-06-16 | 401d? | 90d | finish no earlier than 2006-09-15 | S2 | 3728h | 1006.56h | SAE | Rel-7 | 23.882 |  |  |  |  |
| 249 | 71 | FS on Performance Evaluation of the UE behaviour in high speed trains with speeds up to 350 kmph |  | 261d? | 2005-03-15 A | 2006-03-15 | 80% | 52.2d? | 2005-03-15 | 2006-03-15 | 261d? | 223d | finish no earlier than 2006-03-15 | R4 | 2088h | 1670.4h | RANFS-HSTrains | Rel-7 |  | Mike Vogel | Mike.vogel@vodafone.com | MCC_RAN | TSG |
| 250 | 72 | FS of enhanced support of Video Telephony |  | 481d? | 2004-08-27 A | 2006-06-30 | 35% | 312.65d? | 2004-08-27 | 2005-11-11 | 316d? | 145d | finish no earlier than 2006-06-30 | GP | 3848h | 1346.8h | VIDGER | Rel-7 |  | Stefan Eriksson, Ericsson | stefan.g.eriksson@ericsson.com | Paolo | TSG |
| 251 | 73 | FS on Evolved UTRA and UTRAN |  | 130d? | 2004-12-15 A | 2005-06-15 | 30% | 91d? | 2004-12-15 | 2005-06-15 | 130d? | 418d | finish no earlier than 2005-06-15 | RP | 1040h | 312h | RANFS-Evo | Rel-7 |  | Takehiro Nakamura (NTT DoCoMo) | nakamurata@NTTDOCOMO.CO.JP | MCC_RAN | TSG |

Notes:
- 240: Approved at SP#29. To be shown as feature - END Sept 06
- 241: The WID still calls it a BB, not a Feature.
- 247: RAN work started
- 250: FS started

| ID | WBS | Task | Type | Duration | Start | Finish | Complete | Remaining | Baseline start | Baseline finish | Baseline duration | Total slack | Constraint | Resources | Work | Actual work | Text1 | Text4 | Text5 | Text6 | Text7 | Text8 | Text3 | Text12 |
| --- | --- | --- | --- | --- | --- | --- | --- | --- | --- | --- | --- | --- | --- | --- | --- | --- | --- | --- | --- | --- | --- | --- | --- | --- |
| 252 | 74 | **Study on Videotelephony teleservice** |  | 452d? | 2005-03-15 A | 2006-12-06 | 95% | 22.6d? | 2005-03-15 | 2006-12-06 | 452d? | 32d |  | S1 | 7232h | 6870.4h | VidTel | Kurt Bischinger (T-Mobile) | kurt.bischinger@t-mobile.at | Rel-7 | TSG | Michael |  |  |
| 253 | 74.1 | Study on Videotelephony service requirements |  | 452d? | 2005-03-15 A | 2006-12-06 | 95% | 22.6d? | 2005-03-15 | 2006-12-06 | 452d? | 32d | finish no earlier than 2006-12-06 | S1 | 3616h | 3435.2h | VidTel | Kurt Bischinger (T-Mobile) | kurt.bischinger@t-mobile.at | Rel-7 | TSG | Michael | 22.903 |  |
| 254 | 75 | **Study of Network Selection Principles** |  | 193d? | 2005-03-15 A | 2005-12-08 | 75% | 48.25d? | 2005-03-15 | 2005-12-08 | 193d? | 291d |  | S1 | 3088h | 2272.02h | NetSel | Chris Friel (O2) | chris.friel@o2.com | Rel-7 | TSG | Michael |  |  |
| 255 | 75.1 | Review of Network Selection Principles |  | 193d? | 2005-03-15 A | 2005-12-08 | 75% | 48.25d? | 2005-03-15 | 2005-12-08 | 193d? | 291d | finish no earlier than 2005-12-08 | S1 | 1544h | 1158h | NetSel | Chris Friel (O2) | chris.friel@o2.com | Rel-7 | TSG | Michael | 22.811 |  |
| 256 | 76 | FS on Enhancements to support QoS provisioning over 3GPP/WLAN Interworking |  | 330d? | 2005-03-14 A | 2006-06-16 | 70% | 99d? | 2005-03-14 | 2006-09-11 | 391d? | 155d | finish no earlier than 2006-06-16 | S2 | 2640h | 1848h | WLAN-QOS | Osok Song, Samsung | osok.song@samsung.com | Rel-7 |  | Maurice | 23.836 |  |
| 257 | 77 | FS on Continuous connectivity for packet data users |  | 132d? | 2005-03-15 A | 2005-09-15 A | 100% |  | 2005-03-15 | 2005-09-15 | 132d? |  | finish no earlier than 2005-09-15 | R1 | 1056h | 1056h | RANFS-cont-packet | Joerg Gustrau | joerg.gustrau@siemens.com | Rel-7 | TSG | MCC_RAN |  |  |
| 258 | 78 | FS on UTRA Tower Mounted Amplifier (FDD) |  | 195d? | 2005-06-15 A | 2006-03-15 | 10% | 175.5d? | 2005-06-15 | 2006-03-15 | 195d? | 223d | finish no earlier than 2006-03-15 | R4 | 1560h | 156h | RANFS-TMA | Klas Sjerling | Klas.Sjerling@ericsson.com | Rel-7 | TSG | MCC_RAN |  |  |
| 259 | 79 | Multimedia Priority Service |  | 711d? | 2003-03-28 A | 2005-12-16 | 60% | 284.4d? | 2003-03-28 | 2004-12-16 | 450d? | 285d | finish no earlier than 2005-12-16 | S1 | 5688h | 3412.8h | PRIOR-MM | Jim Garrahan (Telcordia) | jgarraha@telcordia.com | Rel-6 |  | Michael | 22.953 |  |
| 260 | 80 | **Selective Disabling of UE Capabilities** |  | 489.36d? | 2005-01-24 A | 2006-12-08 A | 100% |  | 2005-01-24 | 2006-12-08 | 489.36d? |  |  | S1 | 8308.8h | 8308.8h | SDoUE | Nigel Barnes (Motorola Ltd) | Nigel.Barnes@motorola.com | Rel-7 | TSG | Michael | 22.xxx |  |
| 261 | 80.1 | Stage 1 |  | 393.6d? | 2005-01-24 A | 2006-12-08 A | 100% |  | 2005-01-24 | 2006-12-08 | 393.6d? |  | finish no earlier than 2006-12-08 | S1 | 3148.8h | 3148.8h | SDoUE-CRs | Nigel Barnes (Motorola Ltd) | Nigel.Barnes@motorola.com | Rel-7 | TSG | Michael | 22.011 |  |
| 262 | 80.2 | TR on different possible architectures |  | 195d? | 2005-03-21 A | 2005-12-16 A | 100% |  | 2005-03-21 | 2005-12-16 | 195d? |  | finish no earlier than 2005-12-16 | S2 | 1560h | 1560h | SDoUE |  |  | Rel-7 |  | Maurice | 23.805 |  |
| 263 | 81 | Personal Network Mangement (PNM) |  | 101.2d? | 2005-07-11 A | 2005-12-08 | 50% | 50.6d? | 2005-07-11 | 2005-12-08 | 101.2d? | 291d | finish no earlier than 2005-12-08 | S1 | 809.6h | 404.8h | PNPAN | Armin Toepfer, Vodafone | armin.toepfer@vodafone.com | Rel-7 |  | Mike |  |  |
| 264 | 82 | Multimedia Telephony Capabilities for IMS |  | 101.2d? | 2005-07-11 A | 2005-12-08 | 65% | 35.42d? | 2005-07-11 | 2005-12-08 | 101.2d? | 291d | finish no earlier than 2005-12-08 | S1 | 809.6h | 526.24h | MITE | Peter Bleckert, Ericsson | peter.bleckert @ericsson.com | Rel-7 |  | Mike |  |  |
| 265 | 83 | Transferring of emergency Call data |  | 109d? | 2005-07-11 A | 2005-12-08 | 65% | 38.15d? | 2005-07-11 | 2005-12-08 | 109d? | 291d | finish no earlier than 2005-12-08 | S1 | 872h | 566.8h | eCALL | Steve Vardy, (Motorola S.A.S) | steven.vardy@motorola.com | Rel-7 |  | Mike |  |  |
| 266 | 84 | MBMS Enhancements |  | 109d? | 2005-07-11 A | 2005-12-08 | 25% | 81.75d? | 2005-07-11 | 2005-12-08 | 109d? | 291d | finish no earlier than 2005-12-08 | S1 | 872h | 218h | MBMSE | Liu Hong, China Mobile | liuhongyfw@chinamobile.com | Rel-7 |  | Mike |  |  |
| 267 | 85 | IMS security extensions |  | 118d? | 2005-06-28 A | 2005-12-08 | 60% | 47.2d? | 2005-06-28 | 2005-12-08 | 118d? | 291d | start no earlier than 2005-06-28 | S3 | 944h | 566.4h | IMS-SE | Bengt Sahlin, Ericsson | Bengt.Sahlin@ericsson.com | Rel-7 |  | Mike |  |  |
| 268 | 86 | Multimedia interworking between IMS and CS networks |  | 181d? | 2005-09-23 A | 2006-06-02 | 3% | 175.57d? | 2005-09-23 | 2006-06-02 | 181d? | 165d | finish no earlier than 2006-06-02 | C3 | 1448h | 43.44h | MIW-IMS | Nico Gabriele, Vodafone UK | nico.gabriele@vodafone.com | Rel-7 |  | Seung Don | 29.163 |  |
| 269 | 87 | Study of a SMS Centre for MT SMS |  | 116d? | 2005-10-07 A | 2006-03-17 | 20% | 92.8d? | 2005-10-07 | 2006-03-17 | 116d? | 220d | start no earlier than 2005-10-07 | C4 | 928h | 185.6h | SMS7 | Nick Russell, Vodafone UK | Nick.Russell@vodafone.com | Rel-7 |  | Kimmo | 23.840 |  |
| 270 | 88 | Study of Customised Alerting Tone (CAT) Requirements |  | 1d? | 2005-09-12 A | 2005-09-12 | 15% | 0.85d? |  |  |  | 354d | start no earlier than 2005-09-12 | S1 | 8h | 1.2h | CAT |  |  | Rel-7 |  |  |  |  |
| 271 | 89 | Facilitating Machine to Machine Communication in GSM and UMTS (M2M) |  | 161d? | 2005-11-04 A | 2006-06-16 | 25% | 120.75d? |  |  |  | 155d | finish no earlier than 2006-06-16 | S1 | 1288h | 322h | M2M | Juergen Merkel, Siemens AG |  | Rel-7 |  | Michael | 22.868 |  |
| 272 | 90 | FS on Improvement of the Multimedia Broadcast Multicast Service (MBMS) in UTRAN |  | 131d? | 2005-12-15 | 2006-06-15 |  |  |  |  |  | 156d | finish no earlier than 2006-06-15 | R2 | 1048h |  | MBMSImp | YoungDae Lee, LG | leego@lge.com | Rel-7 |  | MCC_RAN |  |  |
| 273 | 91 | FS on Performance Improvements in Small Cells using HSDPA/EDCH |  | 131d? | 2005-12-15 | 2006-06-15 |  |  |  |  |  | 156d | finish no earlier than 2006-06-15 | R4 | 1048h |  | SMALLCELLS | Marc Grant, Cingular | marc.grant@cingular.com | Rel-7 |  | MCC_RAN |  |  |
| 274 | 92 | FS on Further Improved Performance Requirements for UMTS/HSDPA UE (FDD) |  | 262d? | 2005-12-15 | 2006-12-15 |  |  |  |  |  | 25d | finish no earlier than 2006-12-15 | R4 | 2096h |  | HSDPAUE1 | Marc Grant, Cingular | marc.grant@cingular.com | Rel-7 |  | MCC_RAN |  |  |
| 275 | 93 | **Deleted: FS on applicability of GALILEO for LCS** |  | 484d? | 2003-08-25 A | 2005-06-30 |  | 484d? | 2003-08-25 | 2005-06-30 | 484d? | 406d |  | S2 | 3872h | 1000h | Galileo |  |  | Rel-7 |  |  |  | SP-25 |
| 276 | 93.1 | Deleted - TR on Stage 2 | milestone | 0d? | 2005-06-30 A | 2005-06-30 A | 100% |  | 2005-06-30 | 2005-06-30 | 0d? |  | finish no earlier than 2005-06-30 | S2 |  |  | Galileo |  |  | Rel-7 |  |  |  | SP-25 |
| 277 | 93.2 | deleted - GERAN review of the TR | milestone | 0d? | 2003-08-25 | 2003-08-25 |  |  | 2003-08-25 | 2003-08-25 | 0d? | 890d | finish no earlier than 2003-08-25 | GP |  |  | Galileo |  |  | Rel-7 |  |  |  | SP-26 |

Notes:
- 256: Approved SA#27. BB to be placed next to WLAN-PNA
- 259: Moved from Rel6
- 269: Study WI
- 270: Awaiting MCC SA3 input

| ID | WBS | Task | Type | Duration | Start | Finish | Complete | Remaining | Baseline start | Baseline finish | Baseline duration | Total slack | Constraint | Resources | Work | Actual work | Text1 | Text3 | Text6 | Text12 | Text4 | Text5 | Text7 | Text8 |
| --- | --- | --- | --- | --- | --- | --- | --- | --- | --- | --- | --- | --- | --- | --- | --- | --- | --- | --- | --- | --- | --- | --- | --- | --- |
| 278 | 16.7 | **Deleted - IMS Local services** |  | 1158d? | 2001-01-01 A | 2005-06-08 | 68% | 367.35d? | 2001-01-01 | 2005-06-08 | 1158d? | 422d |  | S2 | 13072h | 5192.02h | IMSLocal | 23.228 | Rel-7 | SP-28 |  |  |  |  |
| 279 | 16.7.1 | Deleted - Stage 2 |  | 325d | 2001-01-01 A | 2002-03-29 A | 100% |  | 2001-01-01 | 2002-03-29 | 325d |  | start no earlier than 2001-01-01 | S2 | 2600h | 2600h | IMSLocal |  | Rel-7 | SP-26 |  |  |  |  |
| 280 | 94.2 | Delete - Stage 3 for IMS Local services |  | 151d? | 2004-11-10 | 2005-06-08 |  |  | 2004-11-10 | 2005-06-08 | 151d? | 422d | finish no earlier than 2005-06-08 | C1 | 1208h |  | IMSLocal |  | Rel-7 | SP-25 | Keith Drage, Lucent | drage@lucent.com |  |  |
| 281 | 95 | Deleted - IMS Phase 3 | milestone | 0d? | 2005-06-08 A | 2005-06-08 A | 100% |  | 2005-06-08 | 2005-06-08 | 0d? |  | finish no earlier than 2005-06-08 | S2 |  |  |  |  | Rel-7 | SP-25 |  |  |  |  |
| 282 | 96 | Deleted - Improvements of Radio Interface | milestone | 0d? | 2004-09-15 A | 2004-09-15 A | 100% |  | 2004-09-15 | 2004-09-15 | 0d? |  | start no earlier than 2004-09-15 | RP |  |  | RInImp |  | Rel-7 | SP-24 |  | Rel-7 | TSG | Cesar |
| 283 | 97 | **Deleted: Generic User Profile Phase 2** |  | 234.4d? | 2005-10-06 A | 2006-08-31 | 65% | 82.04d? | 2005-10-06 | 2006-08-31 | 234.4d | 101.6d |  | C4 | 768h | 499.2h |  |  | Rel-7 | SP-27 |  |  |  | Gaby |
| 284 | 30.4 | Deleted - Stage 3 - Common objects | milestone | 0d | 2005-10-06 A | 2006-08-31 |  | 0d | 2005-10-06 | 2006-08-31 | 0d | 0d | finish no earlier than 2005-10-06 | C4 |  |  |  | 24.241 | Rel-7 | SP-27 |  |  | TSG | Gaby |
| 285 | 97.2 | FS on the TCAPsec Gateway concept |  | 96d? | 2005-10-28 A | 2006-03-10 | 65% | 33.6d? | 2005-10-07 | 2006-03-17 | 116d? | 225d | finish no earlier than 2006-03-10 | C4 | 768h | 499.2h | SEC7-TCAP | 29.800 | Rel-7 |  | Ulrich Wiehe, Siemens | Ulrich.wiehe@gksag.de |  | Kimmo |

Notes:
- 279: DAB - Not yet required in SA2 as it exists in previous releases
- 282: Stage 2 description of Interim conclusion
- 283: Created at TSG#27 by A. Sultan because of the move to Rel-7 of "Common Objects".
- 284: No progress in CN4#26. This have to be moved to Rel-7. It was deleted from WID
- 285: Study WI / TR presented for information in CT#30
